# HRA Project Plan

How a schedule from MS Project changed from version to version. A marks actual dates.

## Version 1 (saved 2011-12-15)

| ID | WBS | Task | Duration | Start | Finish | Predecessors | Complete | Total float | Constraint |
| --- | --- | --- | --- | --- | --- | --- | --- | --- | --- |
| 1 | 1 | **Housing Replacement Analysis Project** | 94d | 2011-10-31 A | 2012-03-20 |  | 43% | 0d |  |
| 2 |  | Project Kickoff Meeting | 1d | 2011-10-31 | 2011-10-31 |  |  | 33.67d |  |
| 3 | 1.2 | **Discovery Phase (as-is)** | 90d | 2011-11-04 A | 2012-03-20 |  | 44% | 0d |  |
| 4 | 1.2.1 | **Business Justification** | 20d | 2011-11-04 A | 2011-12-06 A | 2 | 100% |  |  |
| 5 |  | Write Business Justification | 10d | 2011-11-14 A | 2011-11-25 A | 6 | 100% |  | start no earlier than 2011-11-01 |
| 6 |  | Review Business Justification | 6d | 2011-11-04 A | 2011-11-11 A |  | 100% |  | finish no earlier than 2011-11-11 |
| 7 |  | Obtain Approval from Project Team | 1d | 2011-11-29 A | 2011-11-29 A | 5, 6 | 100% |  | start no earlier than 2011-11-29 |
| 8 |  | Obtain Approval from Project Sponsors | 0d | 2011-12-06 A | 2011-12-06 A | 7 | 100% |  | start no earlier than 2011-12-06 |
| 9 |  | Business Justification completed | 0d | 2011-12-06 A | 2011-12-06 A | 8 | 100% |  |  |
| 10 | 1.2.2 | **Project Scope Document** | 19d | 2011-11-07 A | 2011-12-06 A | 2 | 100% |  |  |
| 11 |  | Write Project Scope Document | 5d | 2011-11-07 A | 2011-11-11 A |  | 100% |  | finish no earlier than 2011-11-11 |
| 12 |  | Review Project Scope Document | 1d | 2011-11-18 A | 2011-11-18 A | 11 | 100% |  | finish no earlier than 2011-11-18 |
| 13 |  | Obtain Approval from Project Team | 1d | 2011-11-29 A | 2011-11-29 A |  | 100% |  | start no earlier than 2011-11-29 |
| 14 |  | Obtain Approval from Project Sponsors | 0d | 2011-12-06 A | 2011-12-06 A |  | 100% |  | start no earlier than 2011-12-06 |
| 15 |  | Project Scope completed | 0d | 2011-12-06 A | 2011-12-06 A |  | 100% |  | start no earlier than 2011-12-06 |
| 16 | 1.2.3 | **As-Is Process Maps** | 65d | 2011-11-29 A | 2012-03-06 | 4, 10 | 25% | 10d |  |
| 17 |  | System (IS&T) | 15d | 2011-11-29 A | 2011-12-19 |  | 82% | 6d |  |
| 18 | 1.2.3.2 | **Housing / Lottery** | 31d | 2012-01-03 | 2012-02-15 | 17 |  | 0d |  |
| 19 |  | Freshman (new to the Institute) | 2d | 2012-01-03 | 2012-01-04 | 17 |  | 0d |  |
| 20 |  | Upperclassman | 2d | 2012-01-05 | 2012-01-06 | 19 |  | 0d |  |
| 21 |  | FSILG | 2d | 2012-01-09 | 2012-01-10 | 20 |  | 0d |  |
| 22 |  | Off Campus Students | 2d | 2012-01-11 | 2012-01-12 | 21 |  | 0d |  |
| 23 |  | Graduate Students | 2d | 2012-01-13 | 2012-01-30 | 22 |  | 0d |  |
| 24 |  | Summer Students | 2d | 2012-01-31 | 2012-02-01 | 23 |  | 0d |  |
| 25 |  | Post-Doctoral / Faculty | 2d | 2012-02-02 | 2012-02-03 | 24 |  | 0d |  |
| 26 |  | Young Students (Legal Minors) | 2d | 2012-02-06 | 2012-02-07 | 25 |  | 0d |  |
| 27 |  | Outside, Non Affiliated Groups | 2d | 2012-02-08 | 2012-02-09 | 26 |  | 0d |  |
| 28 |  | MIT - Affiliated Groups | 2d | 2012-02-10 | 2012-02-13 | 27 |  | 0d |  |
| 29 |  | Visitors | 2d | 2012-02-14 | 2012-02-15 | 28 |  | 0d |  |
| 30 | 1.2.3.3 | **Housing Stakeholder** | 12d | 2012-02-16 | 2012-03-05 |  |  | 0d |  |
| 31 |  | Housing / DS Finance, Billing, & Assessment | 2d | 2012-02-16 | 2012-02-17 | 29 |  | 0d |  |
| 32 |  | Registrar's Office | 2d | 2012-02-21 | 2012-02-22 | 31 |  | 0d |  |
| 33 |  | Student Financial Services | 2d | 2012-02-23 | 2012-02-24 | 32 |  | 0d |  |
| 34 |  | Card Office | 2d | 2012-02-27 | 2012-02-28 | 33 |  | 0d |  |
| 35 |  | Security and Emergency Office | 2d | 2012-02-29 | 2012-03-01 | 34 |  | 0d |  |
| 36 |  | Campus Dining | 2d | 2012-03-02 | 2012-03-05 | 35 |  | 0d |  |
| 37 |  | As-Is Process Maps completed | 0d | 2012-03-06 | 2012-03-06 | 18, 30FS+1d |  | 10d |  |
| 38 |  | Review with Project Team, Stakeholders | 10d | 2012-03-06 | 2012-03-19 | 36 |  | 0d |  |
| 39 |  | Discovery Phase Completed | 0d | 2012-03-20 | 2012-03-20 | 38FS+1d |  | 0d |  |
| 40 |  | Define Phase | 0d | 2012-03-20 | 2012-03-20 | 3 |  | 0d |  |
| 41 |  | Design Phase | 0d | 2012-03-20 | 2012-03-20 | 40 |  | 0d |  |

## Version 2 (saved 2012-02-17)

Last finish 2012-03-20 → 2012-08-30 (+163d).

Added:

| ID | Task | Duration | Start | Finish | Predecessors | Constraint | Resources |
| --- | --- | --- | --- | --- | --- | --- | --- |
| 16 | **Discovery Meetings** | 88d | 2011-12-15 A | 2012-04-24 | 4, 10 |  |  |
| 17 | System Diagram (IS&T) | 7d | 2011-12-15 A | 2012-02-03 |  | finish no earlier than 2012-02-03 | Ross [44%] |
| 30 | **Housing filemaker Databases** | 10d | 2012-02-06 | 2012-02-17 |  |  |  |
| 31 | Master Blaster | 5d | 2012-02-06 | 2012-02-10 |  | start no earlier than 2012-02-06 | Janet |
| 32 | UG Confirmation | 5d | 2012-02-06 | 2012-02-10 |  | start no earlier than 2012-02-06 | Ross [40%] |
| 33 | Conference / Guest | 5d | 2012-02-06 | 2012-02-10 |  | start no earlier than 2012-02-06 | Ross [40%] |
| 34 | Vacancy | 5d | 2012-02-13 | 2012-02-17 |  | start no earlier than 2012-02-13 | Janet |
| 35 | Early Return | 5d | 2012-02-13 | 2012-02-17 |  | start no earlier than 2012-02-13 | Ross |
| 36 | Waiting List | 5d | 2012-02-13 | 2012-02-17 |  | start no earlier than 2012-02-13 | Janet |
| 37 | Front Desk | 5d | 2012-02-13 | 2012-02-17 | 33 |  |  |
| 38 | Housing SISTIM Functionality on Housing | 8d | 2012-02-21 | 2012-03-01 |  | start no earlier than 2012-02-21 | Ross |
| 39 | Housing MITSIS Functionality on Housing | 8d | 2012-02-21 | 2012-03-01 |  | start no earlier than 2012-02-21 | Janet |
| 40 | **CBORD** | 6d | 2012-03-02 | 2012-03-09 | 39 |  |  |
| 41 | Digital Building / Room Setup & Maintenance | 5d | 2012-03-02 | 2012-03-08 |  | start no earlier than 2012-01-23 | Ross [40%] |
| 42 | Room Rate Code Setup & Maintenance | 5d | 2012-03-05 | 2012-03-09 |  | start no earlier than 2012-03-05 | Ross [40%] |
| 43 | Current Security, Roles & Authorization, and structures for housing applications | 5d | 2012-03-05 | 2012-03-09 |  | start no earlier than 2012-03-05 | Ross [40%] |
| 45 | Discuss systems/applications/process flow | 5d | 2012-03-12 | 2012-03-16 |  |  | Janet |
| 46 | Discuss process calendar | 5d | 2012-03-12 | 2012-03-16 |  |  | Janet |
| 47 | Walkthrough of digital Building/Room Setup & Maintenance | 5d | 2012-03-12 | 2012-03-16 |  |  | Janet |
| 48 | Walkthrough of Room Rate Codes Setup & Maintenance | 5d | 2012-03-12 | 2012-03-16 |  |  | Janet |
| 49 | Analysis/review of OTF process | 5d | 2012-03-12 | 2012-03-16 |  |  | Janet |
| 50 | Discuss functionality/efficiency/information gaps in current assessment & OTF process | 5d | 2012-03-12 | 2012-03-16 |  |  | Janet |
| 51 | **Housing Stakeholder - Student Financial Services** | 5d | 2012-03-20 | 2012-03-26 | 44FS+1d |  |  |
| 52 | Assess primary users/roles | 5d | 2012-03-20 | 2012-03-26 |  |  | Ross [40%] |
| 53 | Discuss systems/process flow | 5d | 2012-03-20 | 2012-03-26 |  |  | Ross [40%] |
| 54 | Discuss process calendar | 5d | 2012-03-20 | 2012-03-26 |  |  | Ross [40%] |
| 55 | **Housing Stakeholder - Registrar** | 5d | 2012-03-28 | 2012-04-03 | 51FS+1d |  |  |
| 56 | Evaluate scope of affected data/process/systems | 5d | 2012-03-28 | 2012-04-03 |  |  | Janet |
| 57 | Examine dataflow for MITSIS Directory information | 5d | 2012-03-28 | 2012-04-03 |  |  | Janet |
| 58 | Examine current supporting processes & functionality | 5d | 2012-03-28 | 2012-04-03 |  |  | Janet |
| 59 | Housing Stakeholders - Card Office | 5d | 2012-04-04 | 2012-04-10 | 55 |  | Ross [40%] |
| 60 | Housing Stakeholders - Security and Emergency Office | 5d | 2012-04-11 | 2012-04-17 | 59 |  | Janet |
| 61 | Housing Stakeholders - Campus Dining | 5d | 2012-04-18 | 2012-04-24 | 60 |  | Ross [40%] |
| 62 | **Discovery Phase Documentation** | 45d | 2012-02-17 | 2012-04-20 |  |  |  |
| 64 | Graduate Students | 4.5d | 2012-02-17 | 2012-02-24 |  | start no earlier than 2012-02-17 | Janet [40%] |
| 65 | Undergraduate Students | 4.5d | 2012-02-17 | 2012-02-24 |  | start no earlier than 2012-02-17 | Ross [40%] |
| 66 | Vacancy | 20d | 2012-02-27 | 2012-03-23 | 64 | start no earlier than 2012-02-27 | Janet [40%] |
| 67 | Transfers | 20d | 2012-03-26 | 2012-04-20 | 66 | start no earlier than 2012-02-27 | Janet [40%] |
| 68 | Early Returns | 20d | 2012-02-27 | 2012-03-23 | 65 | start no earlier than 2012-02-27 | Ross [40%] |
| 69 | Wait List | 20d | 2012-03-26 | 2012-04-20 | 68 | start no earlier than 2012-02-27 | Ross [40%] |
| 71 | **Data Catagories that are tracked between systems** | 15d | 2012-03-26 | 2012-04-13 |  |  |  |
| 72 | Housing | 15d | 2012-03-26 | 2012-04-13 |  | start no earlier than 2012-03-26 | Ross [40%] |
| 73 | Biographical | 15d | 2012-03-26 | 2012-04-13 |  | start no earlier than 2012-03-26 | Janet [40%] |
| 74 | Preferences | 15d | 2012-03-26 | 2012-04-13 |  | start no earlier than 2012-03-26 | Ross [40%] |
| 75 | Dual Entry areas / Pain Points | 15d | 2012-03-26 | 2012-04-13 |  | start no earlier than 2012-03-26 | Janet [40%] |
| 76 | Project Wiki | 15d | 2012-03-26 | 2012-04-13 |  | start no earlier than 2012-03-26 | Ross [40%] |

Removed: 17 System (IS&T); 31 Housing / DS Finance, Billing, & Assessment; 32 Registrar's Office; 33 Student Financial Services; 34 Card Office; 35 Security and Emergency Office; 36 Campus Dining

Changed:

| ID | Task | Start | Finish | Duration | Complete | Total float | Predecessors | Other |
| --- | --- | --- | --- | --- | --- | --- | --- | --- |
| 1 | **Housing Replacement Analysis Project** |  | 2012-03-20 → 2012-08-30 (+163d) | 94d → 211d | 43% → 8% |  |  |  |
| 3 | **Discovery Phase (as-is)** |  | 2012-03-20 → 2012-05-03 (+44d) | 90d → 122d | 44% → 8% |  |  |  |
| 18 | **Housing / Lottery** | 2012-01-03 → 2011-12-15 (-19d) | 2012-02-15 → 2012-04-03 (+48d) | 31d → 73d |  | 0d → 22d | System (IS&T) → none |  |
| 19 | Freshman (new to the Institute) | 2012-01-03 → 2011-12-15 (-19d) | 2012-01-04 → 2011-12-16 (-19d) |  |  | 0d → 93d | System (IS&T) → none | constraint none → start no earlier than 2011-12-15; resources Ross [25%] → Ross [40%] |
| 20 | Upperclassman | 2012-01-05 → 2012-04-02 (+88d) | 2012-01-06 → 2012-04-03 (+88d) |  |  | 0d → 22d | 19 → none | constraint none → start no earlier than 2012-04-02; resources Ross → Ross [40%] |
| 21 | FSILG | 2012-01-09 → 2012-04-02 (+84d) | 2012-01-10 → 2012-04-03 (+84d) |  |  | 0d → 22d | 20 → none | constraint none → start no earlier than 2012-04-02 |
| 22 | Off Campus Students | 2012-01-11 → 2012-04-02 (+82d) | 2012-01-12 → 2012-04-03 (+82d) |  |  | 0d → 22d | 21 → none | constraint none → start no earlier than 2012-04-02 |
| 23 | Graduate Students | 2012-01-13 → 2012-04-02 (+80d) | 2012-01-30 → 2012-04-03 (+64d) |  |  | 0d → 22d | 22 → none | constraint none → start no earlier than 2012-04-02 |
| 24 | Summer Students | 2012-01-31 → 2012-04-02 (+62d) | 2012-02-01 → 2012-04-03 (+62d) |  |  | 0d → 22d | 23 → none | constraint none → start no earlier than 2012-04-02 |
| 25 | Post-Doctoral / Faculty | 2012-02-02 → 2012-04-02 (+60d) | 2012-02-03 → 2012-04-03 (+60d) |  |  | 0d → 22d | 24 → none | constraint none → start no earlier than 2012-04-02 |
| 26 | Young Students (Legal Minors) | 2012-02-06 → 2012-04-02 (+56d) | 2012-02-07 → 2012-04-03 (+56d) |  |  | 0d → 22d | 25 → none | constraint none → start no earlier than 2012-04-02 |
| 27 | Outside, Non Affiliated Groups | 2012-02-08 → 2012-04-02 (+54d) | 2012-02-09 → 2012-04-03 (+54d) |  |  | 0d → 22d | 26 → none | constraint none → start no earlier than 2012-04-02 |
| 28 | MIT - Affiliated Groups | 2012-02-10 → 2012-04-02 (+52d) | 2012-02-13 → 2012-04-03 (+50d) |  |  | 0d → 22d | 27 → none | constraint none → start no earlier than 2012-04-02 |
| 29 | Visitors | 2012-02-14 → 2012-04-02 (+48d) | 2012-02-15 → 2012-04-03 (+48d) |  |  | 0d → 22d | 28 → none | constraint none → start no earlier than 2012-04-02 |
| 44 | **Housing Stakeholder - HFS Accounting (David Bull's Group)** | 2012-02-16 → 2012-03-12 (+25d) | 2012-03-05 → 2012-03-16 (+11d) | 12d → 5d |  | 0d → 7d | none → 40 | was named Housing Stakeholder |
| 63 | **As-Is Process Maps** | 2011-11-29 A → 2012-02-17 (+80d) | 2012-03-06 → 2012-04-20 (+45d) | 65d → 45d | 25% → 0% | 10d → 0d | 4, 10 → none |  |
| 70 | As-Is Process Maps completed | 2012-03-06 → 2012-04-20 (+45d) | 2012-03-06 → 2012-04-20 (+45d) |  |  | 10d → 0d | 18, 44FS+1d → 64, 65, 66, 67, 68, 69 |  |
| 77 | Review with Project Team, Stakeholders | 2012-03-06 → 2012-04-23 (+48d) | 2012-03-19 → 2012-04-27 (+39d) | 10d → 5d |  |  | Campus Dining → 75, 76, 71, 63 | resources Ross; Robin; Jonathan → none |
| 78 | Discovery Phase Completed | 2012-03-20 → 2012-05-03 (+44d) | 2012-03-20 → 2012-05-03 (+44d) |  |  |  | 77FS+1d → 77FS+4d |  |
| 79 | Define Phase | 2012-03-20 → 2012-06-28 (+100d) | 2012-03-20 → 2012-06-28 (+100d) |  |  |  | 3 → 3FS+40d |  |
| 80 | Design Phase | 2012-03-20 → 2012-08-30 (+163d) | 2012-03-20 → 2012-08-30 (+163d) |  |  |  | 79 → 79FS+45d |  |

## Version 3 (saved 2012-02-24)

Last finish 2012-08-30 → 2012-11-19 (+81d).

Changed:

| ID | Task | Start | Finish | Duration | Complete | Total float | Predecessors |
| --- | --- | --- | --- | --- | --- | --- | --- |
| 1 | **Housing Replacement Analysis Project** |  | 2012-08-30 → 2012-11-19 (+81d) | 211d → 268d | 8% → 6% |  |  |
| 3 | **Discovery Phase (as-is)** |  | 2012-05-03 → 2012-07-02 (+60d) | 122d → 164d |  |  |  |
| 16 | **Discovery Meetings** |  | 2012-04-24 → 2012-04-30 (+6d) | 88d → 92d |  | 7d → 0d |  |
| 40 | **Housing Stakeholder - HFS Accounting (David Bull's Group)** | 2012-03-12 → 2012-03-02 (-10d) | 2012-03-16 → 2012-03-08 (-8d) |  |  | 7d → 0d | 58 → 39 |
| 41 | Discuss systems/applications/process flow | 2012-03-12 → 2012-03-02 (-10d) | 2012-03-16 → 2012-03-08 (-8d) |  |  | 7d → 0d |  |
| 42 | Discuss process calendar | 2012-03-12 → 2012-03-02 (-10d) | 2012-03-16 → 2012-03-08 (-8d) |  |  | 7d → 0d |  |
| 43 | Walkthrough of digital Building/Room Setup & Maintenance | 2012-03-12 → 2012-03-02 (-10d) | 2012-03-16 → 2012-03-08 (-8d) |  |  | 7d → 0d |  |
| 44 | Walkthrough of Room Rate Codes Setup & Maintenance | 2012-03-12 → 2012-03-02 (-10d) | 2012-03-16 → 2012-03-08 (-8d) |  |  | 7d → 0d |  |
| 45 | Analysis/review of OTF process | 2012-03-12 → 2012-03-02 (-10d) | 2012-03-16 → 2012-03-08 (-8d) |  |  | 7d → 0d |  |
| 46 | Discuss functionality/efficiency/information gaps in current assessment & OTF process | 2012-03-12 → 2012-03-02 (-10d) | 2012-03-16 → 2012-03-08 (-8d) |  |  | 7d → 0d |  |
| 47 | **Housing Stakeholder - Student Financial Services** | 2012-03-20 → 2012-03-12 (-8d) | 2012-03-26 → 2012-03-16 (-10d) |  |  | 7d → 0d |  |
| 48 | Assess primary users/roles | 2012-03-20 → 2012-03-12 (-8d) | 2012-03-26 → 2012-03-16 (-10d) |  |  | 7d → 0d |  |
| 49 | Discuss systems/process flow | 2012-03-20 → 2012-03-12 (-8d) | 2012-03-26 → 2012-03-16 (-10d) |  |  | 7d → 0d |  |
| 50 | Discuss process calendar | 2012-03-20 → 2012-03-12 (-8d) | 2012-03-26 → 2012-03-16 (-10d) |  |  | 7d → 0d |  |
| 51 | **Housing Stakeholder - Registrar** | 2012-03-28 → 2012-03-20 (-8d) | 2012-04-03 → 2012-03-26 (-8d) |  |  | 7d → 0d |  |
| 52 | Evaluate scope of affected data/process/systems | 2012-03-28 → 2012-03-20 (-8d) | 2012-04-03 → 2012-03-26 (-8d) |  |  | 7d → 0d |  |
| 53 | Examine dataflow for MITSIS Directory information | 2012-03-28 → 2012-03-20 (-8d) | 2012-04-03 → 2012-03-26 (-8d) |  |  | 7d → 0d |  |
| 54 | Examine current supporting processes & functionality | 2012-03-28 → 2012-03-20 (-8d) | 2012-04-03 → 2012-03-26 (-8d) |  |  | 7d → 0d |  |
| 55 | Housing Stakeholders - Card Office | 2012-04-04 → 2012-03-27 (-8d) | 2012-04-10 → 2012-04-02 (-8d) |  |  | 7d → 0d |  |
| 56 | Housing Stakeholders - Security and Emergency Office | 2012-04-11 → 2012-04-03 (-8d) | 2012-04-17 → 2012-04-09 (-8d) |  |  | 7d → 0d |  |
| 57 | Housing Stakeholders - Campus Dining | 2012-04-18 → 2012-04-10 (-8d) | 2012-04-24 → 2012-04-16 (-8d) |  |  | 7d → 0d |  |
| 58 | **CBORD** | 2012-03-02 → 2012-04-17 (+46d) | 2012-03-09 → 2012-04-30 (+52d) | 6d → 10d |  | 7d → 0d | 39 → 57 |
| 59 | Digital Building / Room Setup & Maintenance | 2012-03-02 → 2012-04-17 (+46d) | 2012-03-08 → 2012-04-30 (+53d) | 5d → 10d |  | 8d → 0d |  |
| 60 | Room Rate Code Setup & Maintenance | 2012-03-05 → 2012-04-17 (+43d) | 2012-03-09 → 2012-04-17 (+39d) | 5d → 1d |  | 7d → 9d |  |
| 61 | Current Security, Roles & Authorization, and structures for housing applications | 2012-03-05 → 2012-04-17 (+43d) | 2012-03-09 → 2012-04-30 (+52d) | 5d → 10d |  | 7d → 0d |  |
| 62 | **Discovery Phase Documentation** | 2012-02-17 → 2012-04-17 (+60d) | 2012-04-20 → 2012-06-25 (+66d) | 45d → 50d |  |  | none → 16FS-10d |
| 63 | **As-Is Process Maps** | 2012-02-17 → 2012-04-17 (+60d) | 2012-04-20 → 2012-05-28 (+38d) | 45d → 30d |  |  |  |
| 64 | Graduate Students | 2012-02-17 → 2012-04-17 (+60d) | 2012-02-24 → 2012-04-30 (+66d) | 4.5d → 10d |  | 0.5d → 0d |  |
| 65 | Undergraduate Students | 2012-02-17 → 2012-04-17 (+60d) | 2012-02-24 → 2012-04-30 (+66d) | 4.5d → 10d |  | 0.5d → 0d |  |
| 66 | Vacancy | 2012-02-27 → 2012-05-01 (+64d) | 2012-03-23 → 2012-05-14 (+52d) | 20d → 10d |  |  |  |
| 67 | Transfers | 2012-03-26 → 2012-05-15 (+50d) | 2012-04-20 → 2012-05-28 (+38d) | 20d → 10d |  |  |  |
| 68 | Early Returns | 2012-02-27 → 2012-05-01 (+64d) | 2012-03-23 → 2012-05-14 (+52d) | 20d → 10d |  |  |  |
| 69 | Wait List | 2012-03-26 → 2012-05-15 (+50d) | 2012-04-20 → 2012-05-28 (+38d) | 20d → 10d |  |  |  |
| 70 | As-Is Process Maps completed | 2012-04-20 → 2012-05-28 (+38d) | 2012-04-20 → 2012-05-28 (+38d) |  |  |  |  |
| 71 | **Data Catagories that are tracked between systems** | 2012-03-26 → 2012-05-29 (+64d) | 2012-04-13 → 2012-06-25 (+73d) | 15d → 20d |  | 5d → 0d | none → 63 |
| 72 | Housing | 2012-03-26 → 2012-05-29 (+64d) | 2012-04-13 → 2012-06-25 (+73d) | 15d → 20d |  | 5d → 0d |  |
| 73 | Biographical | 2012-03-26 → 2012-05-29 (+64d) | 2012-04-13 → 2012-06-25 (+73d) | 15d → 20d |  | 5d → 0d |  |
| 74 | Preferences | 2012-03-26 → 2012-05-29 (+64d) | 2012-04-13 → 2012-06-25 (+73d) | 15d → 20d |  | 5d → 0d |  |
| 75 | Dual Entry areas / Pain Points | 2012-03-26 → 2012-05-29 (+64d) | 2012-04-13 → 2012-06-25 (+73d) | 15d → 20d |  | 5d → 0d | none → 63 |
| 76 | Project Wiki | 2012-03-26 → 2012-05-29 (+64d) | 2012-04-13 → 2012-06-25 (+73d) | 15d → 20d |  | 5d → 0d | none → 63 |
| 77 | Review with Project Team, Stakeholders | 2012-04-23 → 2012-06-26 (+64d) | 2012-04-27 → 2012-07-02 (+66d) |  |  |  | 75, 76, 71, 63 → 62 |
| 78 | Discovery Phase Completed | 2012-05-03 → 2012-07-02 (+60d) | 2012-05-03 → 2012-07-02 (+60d) |  |  |  | 77FS+4d → 77 |
| 79 | Define Phase | 2012-06-28 → 2012-07-03 (+5d) | 2012-06-28 → 2012-09-10 (+74d) | 0d → 50d |  |  | 3FS+40d → 78 |
| 80 | Design Phase | 2012-08-30 → 2012-09-11 (+12d) | 2012-08-30 → 2012-11-19 (+81d) | 0d → 50d |  |  | 79FS+45d → 79 |

## Version 4 (saved 2012-03-15)

Last finish 2012-11-19 → 2012-11-15 (-4d). Complete tasks 10 → 26.

Added:

| ID | Task | Duration | Start | Finish | Predecessors | Resources |
| --- | --- | --- | --- | --- | --- | --- |
| 62 | House Managers | 1d | 2012-05-02 | 2012-05-02 | 58 | Janet [40%] |
| 63 | FSILG | 1d | 2012-05-03 | 2012-05-03 | 62 | Janet [40%] |

Changed:

| ID | Task | Start | Finish | Duration | Complete | Total float | Predecessors | Other |
| --- | --- | --- | --- | --- | --- | --- | --- | --- |
| 1 | **Housing Replacement Analysis Project** |  | 2012-11-19 → 2012-11-15 (-4d) | 268d → 266d | 6% → 23% |  |  |  |
| 3 | **Discovery Phase (as-is)** |  | 2012-07-02 → 2012-06-28 (-4d) | 164d → 162d | 8% → 29% |  |  |  |
| 16 | **Discovery Meetings** | 2011-12-15 A → 2011-12-06 A (-9d) | 2012-04-30 → 2012-05-03 (+3d) | 92d → 102d | 2% → 46% |  |  |  |
| 17 | System Diagram (IS&T) |  |  |  |  | 60d → 61d |  | constraint finish no earlier than 2012-02-03 → none |
| 18 | **Housing / Lottery** | 2011-12-15 → 2011-12-06 A (-9d) | 2012-04-03 → 2011-12-16 (-109d) | 73d → 9d | 0% → 9% | 19d → 91d |  |  |
| 19 | Freshman (new to the Institute) | 2011-12-15 A | 2011-12-16 A |  | 0% → 100% | 90d → none |  |  |
| 20 | Upperclassman | 2012-04-02 → 2011-12-06 (-118d) | 2012-04-03 → 2011-12-07 (-118d) |  |  | 19d → 98d |  | constraint start no earlier than 2012-04-02 → none |
| 21 | FSILG | 2012-04-02 → 2011-12-06 (-118d) | 2012-04-03 → 2011-12-07 (-118d) |  |  | 19d → 98d |  | constraint start no earlier than 2012-04-02 → none |
| 22 | Off Campus Students | 2012-04-02 → 2011-12-06 (-118d) | 2012-04-03 → 2011-12-07 (-118d) |  |  | 19d → 98d |  | constraint start no earlier than 2012-04-02 → none |
| 23 | Graduate Students | 2012-04-02 → 2011-12-06 (-118d) | 2012-04-03 → 2011-12-07 (-118d) |  |  | 19d → 98d |  | constraint start no earlier than 2012-04-02 → none |
| 24 | Summer Students | 2012-04-02 → 2011-12-06 (-118d) | 2012-04-03 → 2011-12-07 (-118d) |  |  | 19d → 98d |  | constraint start no earlier than 2012-04-02 → none |
| 25 | Post-Doctoral / Faculty | 2012-04-02 → 2011-12-06 (-118d) | 2012-04-03 → 2011-12-07 (-118d) |  |  | 19d → 98d |  | constraint start no earlier than 2012-04-02 → none |
| 26 | Young Students (Legal Minors) | 2012-04-02 → 2011-12-06 (-118d) | 2012-04-03 → 2011-12-07 (-118d) |  |  | 19d → 98d |  | constraint start no earlier than 2012-04-02 → none |
| 27 | Outside, Non Affiliated Groups | 2012-04-02 → 2011-12-06 (-118d) | 2012-04-03 → 2011-12-07 (-118d) |  |  | 19d → 98d |  | constraint start no earlier than 2012-04-02 → none |
| 28 | MIT - Affiliated Groups | 2012-04-02 → 2011-12-06 (-118d) | 2012-04-03 → 2011-12-07 (-118d) |  |  | 19d → 98d |  | constraint start no earlier than 2012-04-02 → none |
| 29 | Visitors | 2012-04-02 → 2011-12-06 (-118d) | 2012-04-03 → 2011-12-07 (-118d) |  |  | 19d → 98d |  | constraint start no earlier than 2012-04-02 → none |
| 30 | **Housing filemaker Databases** | 2012-02-06 A | 2012-02-17 A |  | 0% → 100% | 50d → none |  |  |
| 31 | Master Blaster | 2012-02-06 A | 2012-02-10 A |  | 0% → 100% | 55d → none |  |  |
| 32 | UG Confirmation | 2012-02-06 A | 2012-02-10 A |  | 0% → 100% | 55d → none |  |  |
| 33 | Conference / Guest | 2012-02-06 A | 2012-02-10 A |  | 0% → 100% | 50d → none |  |  |
| 34 | Vacancy | 2012-02-13 A | 2012-02-17 A |  | 0% → 100% | 50d → none |  |  |
| 35 | Early Return | 2012-02-13 A | 2012-02-17 A |  | 0% → 100% | 50d → none |  |  |
| 36 | Waiting List | 2012-02-13 A | 2012-02-17 A |  | 0% → 100% | 50d → none |  |  |
| 37 | Front Desk | 2012-02-13 A | 2012-02-17 A |  | 0% → 100% | 50d → none | 33 → none | constraint none → start no earlier than 2012-02-13; resources none → Ross |
| 38 | Housing SISTIM Functionality on Housing | 2012-02-21 A | 2012-03-01 A |  | 0% → 100% | 42d → none |  |  |
| 39 | Housing MITSIS Functionality on Housing | 2012-02-21 A | 2012-03-01 A |  | 0% → 100% | 0d → none |  |  |
| 40 | **Housing Stakeholder - HFS Accounting (David Bull's Group)** | 2012-03-02 → 2012-03-05 A (+3d) | 2012-03-08 → 2012-03-09 A (+1d) |  | 0% → 100% | 0d → none | 39 → 39FS+1d |  |
| 41 | Discuss systems/applications/process flow | 2012-03-02 → 2012-03-05 A (+3d) | 2012-03-08 → 2012-03-09 A (+1d) |  | 0% → 100% | 0d → none |  |  |
| 42 | Discuss process calendar | 2012-03-02 → 2012-03-05 A (+3d) | 2012-03-08 → 2012-03-09 A (+1d) |  | 0% → 100% | 0d → none |  |  |
| 43 | Walkthrough of digital Building/Room Setup & Maintenance | 2012-03-02 → 2012-03-05 A (+3d) | 2012-03-08 → 2012-03-09 A (+1d) |  | 0% → 100% | 0d → none |  |  |
| 44 | Walkthrough of Room Rate Codes Setup & Maintenance | 2012-03-02 → 2012-03-05 A (+3d) | 2012-03-08 → 2012-03-09 A (+1d) |  | 0% → 100% | 0d → none |  |  |
| 45 | Analysis/review of OTF process | 2012-03-02 → 2012-03-05 A (+3d) | 2012-03-08 → 2012-03-09 A (+1d) |  | 0% → 100% | 0d → none |  |  |
| 46 | Discuss functionality/efficiency/information gaps in current assessment & OTF process | 2012-03-02 → 2012-03-05 A (+3d) | 2012-03-08 → 2012-03-09 A (+1d) |  | 0% → 100% | 0d → none |  |  |
| 47 | **Housing Stakeholder - Student Financial Services** | 2012-03-12 → 2012-03-13 (+1d) | 2012-03-16 → 2012-03-19 (+3d) |  |  |  |  |  |
| 48 | Assess primary users/roles | 2012-03-12 → 2012-03-13 (+1d) | 2012-03-16 → 2012-03-19 (+3d) |  |  |  |  |  |
| 49 | Discuss systems/process flow | 2012-03-12 → 2012-03-13 (+1d) | 2012-03-16 → 2012-03-19 (+3d) |  |  |  |  |  |
| 50 | Discuss process calendar | 2012-03-12 → 2012-03-13 (+1d) | 2012-03-16 → 2012-03-19 (+3d) |  |  |  |  |  |
| 51 | **Housing Stakeholder - Registrar** | 2012-03-20 → 2012-03-21 (+1d) | 2012-03-26 → 2012-03-27 (+1d) |  |  |  |  |  |
| 52 | Evaluate scope of affected data/process/systems | 2012-03-20 → 2012-03-21 (+1d) | 2012-03-26 → 2012-03-27 (+1d) |  |  |  |  |  |
| 53 | Examine dataflow for MITSIS Directory information | 2012-03-20 → 2012-03-21 (+1d) | 2012-03-26 → 2012-03-27 (+1d) |  |  |  |  |  |
| 54 | Examine current supporting processes & functionality | 2012-03-20 → 2012-03-21 (+1d) | 2012-03-26 → 2012-03-27 (+1d) |  |  |  |  |  |
| 55 | Housing Stakeholders - Card Office | 2012-03-27 → 2012-03-28 (+1d) | 2012-04-02 → 2012-04-03 (+1d) |  |  |  |  |  |
| 56 | Housing Stakeholders - Security and Emergency Office | 2012-04-03 → 2012-04-04 (+1d) | 2012-04-09 → 2012-04-10 (+1d) |  |  |  |  |  |
| 57 | Housing Stakeholders - Campus Dining | 2012-04-10 → 2012-04-11 (+1d) | 2012-04-16 → 2012-04-17 (+1d) |  |  |  |  |  |
| 58 | **CBORD** | 2012-04-17 → 2012-04-18 (+1d) | 2012-04-30 → 2012-05-01 (+1d) |  |  |  |  |  |
| 59 | Digital Building / Room Setup & Maintenance | 2012-04-17 → 2012-04-18 (+1d) | 2012-04-30 → 2012-05-01 (+1d) |  |  |  |  |  |
| 60 | Room Rate Code Setup & Maintenance | 2012-04-17 → 2012-04-18 (+1d) | 2012-04-17 → 2012-05-01 (+14d) | 1d → 10d |  | 9d → 0d |  |  |
| 61 | Current Security, Roles & Authorization, and structures for housing applications | 2012-04-17 → 2012-04-18 (+1d) | 2012-04-30 → 2012-05-01 (+1d) |  |  |  |  |  |
| 64 | **Discovery Phase Documentation** | 2012-04-17 → 2012-04-13 (-4d) | 2012-06-25 → 2012-06-21 (-4d) |  |  |  | 16FS-10d → 16FS-15d |  |
| 65 | **As-Is Process Maps** | 2012-04-17 → 2012-04-13 (-4d) | 2012-05-28 → 2012-05-24 (-4d) |  |  |  |  |  |
| 66 | Graduate Students | 2012-04-17 → 2012-04-13 (-4d) | 2012-04-30 → 2012-04-26 (-4d) |  |  |  |  |  |
| 67 | Undergraduate Students | 2012-04-17 → 2012-04-13 (-4d) | 2012-04-30 → 2012-04-26 (-4d) |  |  |  |  |  |
| 68 | Vacancy | 2012-05-01 → 2012-04-27 (-4d) | 2012-05-14 → 2012-05-10 (-4d) |  |  |  |  |  |
| 69 | Transfers | 2012-05-15 → 2012-05-11 (-4d) | 2012-05-28 → 2012-05-24 (-4d) |  |  |  |  |  |
| 70 | Early Returns | 2012-05-01 → 2012-04-27 (-4d) | 2012-05-14 → 2012-05-10 (-4d) |  |  |  |  |  |
| 71 | Wait List | 2012-05-15 → 2012-05-11 (-4d) | 2012-05-28 → 2012-05-24 (-4d) |  |  |  |  |  |
| 72 | As-Is Process Maps completed | 2012-05-28 → 2012-05-24 (-4d) | 2012-05-28 → 2012-05-24 (-4d) |  |  |  |  |  |
| 73 | **Data Catagories that are tracked between systems** | 2012-05-29 → 2012-05-25 (-4d) | 2012-06-25 → 2012-06-21 (-4d) |  |  |  |  |  |
| 74 | Housing | 2012-05-29 → 2012-05-25 (-4d) | 2012-06-25 → 2012-06-21 (-4d) |  |  |  |  |  |
| 75 | Biographical | 2012-05-29 → 2012-05-25 (-4d) | 2012-06-25 → 2012-06-21 (-4d) |  |  |  |  |  |
| 76 | Preferences | 2012-05-29 → 2012-05-25 (-4d) | 2012-06-25 → 2012-06-21 (-4d) |  |  |  |  |  |
| 77 | Dual Entry areas / Pain Points | 2012-05-29 → 2012-05-25 (-4d) | 2012-06-25 → 2012-06-21 (-4d) |  |  |  |  |  |
| 78 | Project Wiki | 2012-05-29 → 2012-05-25 (-4d) | 2012-06-25 → 2012-06-21 (-4d) |  |  |  |  |  |
| 79 | Review with Project Team, Stakeholders | 2012-06-26 → 2012-06-22 (-4d) | 2012-07-02 → 2012-06-28 (-4d) |  |  |  |  |  |
| 80 | Discovery Phase Completed | 2012-07-02 → 2012-06-28 (-4d) | 2012-07-02 → 2012-06-28 (-4d) |  |  |  |  |  |
| 81 | Define Phase | 2012-07-03 → 2012-06-29 (-4d) | 2012-09-10 → 2012-09-06 (-4d) |  |  |  |  |  |
| 82 | Design Phase | 2012-09-11 → 2012-09-07 (-4d) | 2012-11-19 → 2012-11-15 (-4d) |  |  |  |  |  |

## Version 5 (saved 2012-03-22)

Last finish stays 2012-11-15. Complete tasks 26 → 32.

Changed:

| ID | Task | Start | Finish | Complete | Total float |
| --- | --- | --- | --- | --- | --- |
| 1 | **Housing Replacement Analysis Project** |  |  | 23% → 29% |  |
| 3 | **Discovery Phase (as-is)** |  |  | 29% → 37% |  |
| 16 | **Discovery Meetings** |  |  | 46% → 62% |  |
| 47 | **Housing Stakeholder - Student Financial Services** | 2012-03-13 A | 2012-03-19 A | 0% → 100% | 0d → none |
| 48 | Assess primary users/roles | 2012-03-13 A | 2012-03-19 A | 0% → 100% | 0d → none |
| 49 | Discuss systems/process flow | 2012-03-13 A | 2012-03-19 A | 0% → 100% | 0d → none |
| 50 | Discuss process calendar | 2012-03-13 A | 2012-03-19 A | 0% → 100% | 0d → none |
| 51 | **Housing Stakeholder - Registrar** | 2012-03-21 A | 2012-03-27 A | 0% → 100% | 0d → none |
| 52 | Evaluate scope of affected data/process/systems | 2012-03-21 A | 2012-03-27 A | 0% → 100% | 0d → none |
| 53 | Examine dataflow for MITSIS Directory information | 2012-03-21 A | 2012-03-27 A | 0% → 100% | 0d → none |
| 54 | Examine current supporting processes & functionality | 2012-03-21 A | 2012-03-27 A | 0% → 100% | 0d → none |

## Version 6 (saved 2012-04-02)

Last finish 2012-11-15 → 2012-12-05 (+20d). Complete tasks 32 → 33.

Added:

| ID | Task | Duration | Start | Finish | Constraint |
| --- | --- | --- | --- | --- | --- |
| 57 | Housing Stakeholders - Tech Cash | 1d | 2012-04-04 | 2012-04-04 | start no earlier than 2012-04-04 |
| 59 | GRAD House Managers | 1d | 2012-04-17 | 2012-04-17 | start no earlier than 2012-04-17 |
| 62 | Dean On Call | 1d | 2012-05-09 | 2012-05-09 | start no earlier than 2012-05-09 |

Changed:

| ID | Task | Start | Finish | Duration | Complete | Total float | Predecessors | Other |
| --- | --- | --- | --- | --- | --- | --- | --- | --- |
| 1 | **Housing Replacement Analysis Project** |  | 2012-11-15 → 2012-12-05 (+20d) | 266d → 280d | 29% → 31% |  |  |  |
| 3 | **Discovery Phase (as-is)** |  | 2012-06-28 → 2012-07-18 (+20d) | 162d → 176d | 37% → 40% |  |  |  |
| 16 | **Discovery Meetings** | 2011-12-06 A → 2011-12-15 A (+9d) | 2012-05-03 → 2012-05-23 (+20d) | 102d → 109d | 62% → 70% |  |  |  |
| 18 | **Housing / Lottery** | 2011-12-06 A → 2011-12-15 A (+9d) | 2011-12-16 → 2012-04-09 (+115d) | 9d → 77d | 9% → 17% | 91d → 32d |  |  |
| 20 | Upperclassman | 2011-12-06 → 2012-04-09 (+125d) | 2011-12-07 → 2012-04-09 (+124d) | 2d → 1d |  | 98d → 32d |  | constraint none → start no earlier than 2012-04-09 |
| 21 | FSILG | 2011-12-06 → 2012-04-09 (+125d) | 2011-12-07 → 2012-04-09 (+124d) | 2d → 1d |  | 98d → 32d |  | constraint none → start no earlier than 2012-04-09 |
| 22 | Off Campus Students | 2011-12-06 → 2012-04-09 (+125d) | 2011-12-07 → 2012-04-09 (+124d) | 2d → 1d |  | 98d → 32d |  | constraint none → start no earlier than 2012-04-09 |
| 23 | Graduate Students | 2011-12-06 → 2012-04-09 (+125d) | 2011-12-07 → 2012-04-09 (+124d) | 2d → 1d |  | 98d → 32d |  | constraint none → start no earlier than 2012-04-09 |
| 24 | Summer Students | 2011-12-06 → 2012-04-09 (+125d) | 2011-12-07 → 2012-04-09 (+124d) | 2d → 1d |  | 98d → 32d |  | constraint none → start no earlier than 2012-04-09 |
| 25 | Post-Doctoral / Faculty | 2011-12-06 → 2012-04-09 (+125d) | 2011-12-07 → 2012-04-09 (+124d) | 2d → 1d |  | 98d → 32d |  | constraint none → start no earlier than 2012-04-09 |
| 26 | Young Students (Legal Minors) | 2011-12-06 → 2012-04-09 (+125d) | 2011-12-07 → 2012-04-09 (+124d) | 2d → 1d |  | 98d → 32d |  | constraint none → start no earlier than 2012-04-09 |
| 27 | Outside, Non Affiliated Groups | 2011-12-06 → 2012-04-09 (+125d) | 2011-12-07 → 2012-04-09 (+124d) | 2d → 1d |  | 98d → 32d |  | constraint none → start no earlier than 2012-04-09 |
| 28 | MIT - Affiliated Groups | 2011-12-06 → 2012-04-09 (+125d) | 2011-12-07 → 2012-04-09 (+124d) | 2d → 1d |  | 98d → 32d |  | constraint none → start no earlier than 2012-04-09 |
| 29 | Visitors | 2011-12-06 → 2012-04-09 (+125d) | 2011-12-07 → 2012-04-09 (+124d) | 2d → 1d |  | 98d → 32d |  | constraint none → start no earlier than 2012-04-09 |
| 55 | Housing Stakeholders - Card Office / SEMO I | 2012-03-28 → 2012-03-23 A (-5d) | 2012-04-03 → 2012-03-23 A (-11d) | 5d → 1d | 0% → 100% | 0d → none | 51 → none | was named Housing Stakeholders - Card Office; constraint none → start no earlier than 2012-03-23 |
| 56 | Housing Stakeholders - Campus Dining | 2012-04-11 → 2012-04-04 (-7d) | 2012-04-17 → 2012-04-04 (-13d) | 5d → 1d |  | 0d → 35d | 61 → none | constraint none → start no earlier than 2012-04-04 |
| 58 | UG House Managers | 2012-05-02 → 2012-04-12 (-20d) | 2012-05-02 → 2012-04-12 (-20d) |  |  | 0d → 29d | 63 → none | was named House Managers; constraint none → start no earlier than 2012-04-12 |
| 60 | FSILG | 2012-05-03 → 2012-04-18 (-15d) | 2012-05-03 → 2012-04-18 (-15d) |  |  | 0d → 25d | 58 → none | constraint none → start no earlier than 2012-04-18 |
| 61 | Housing Stakeholders - Card Office / SEMO II | 2012-04-04 → 2012-04-23 (+19d) | 2012-04-10 → 2012-04-23 (+13d) | 5d → 1d |  | 0d → 22d | 55 → none | was named Housing Stakeholders - Security and Emergency Office; constraint none → start no earlier than 2012-04-23 |
| 63 | **CBORD** | 2012-04-18 → 2012-05-10 (+22d) | 2012-05-01 → 2012-05-23 (+22d) |  |  |  | 56 → 62 |  |
| 64 | Digital Building / Room Setup & Maintenance | 2012-04-18 → 2012-05-10 (+22d) | 2012-05-01 → 2012-05-23 (+22d) |  |  |  |  |  |
| 65 | Room Rate Code Setup & Maintenance | 2012-04-18 → 2012-05-10 (+22d) | 2012-05-01 → 2012-05-23 (+22d) |  |  |  |  |  |
| 66 | Current Security, Roles & Authorization, and structures for housing applications | 2012-04-18 → 2012-05-10 (+22d) | 2012-05-01 → 2012-05-23 (+22d) |  |  |  |  |  |
| 67 | **Discovery Phase Documentation** | 2012-04-13 → 2012-05-03 (+20d) | 2012-06-21 → 2012-07-11 (+20d) |  |  |  |  |  |
| 68 | **As-Is Process Maps** | 2012-04-13 → 2012-05-03 (+20d) | 2012-05-24 → 2012-06-13 (+20d) |  |  |  |  |  |
| 69 | Graduate Students | 2012-04-13 → 2012-05-03 (+20d) | 2012-04-26 → 2012-05-16 (+20d) |  |  |  |  |  |
| 70 | Undergraduate Students | 2012-04-13 → 2012-05-03 (+20d) | 2012-04-26 → 2012-05-16 (+20d) |  |  |  |  |  |
| 71 | Vacancy | 2012-04-27 → 2012-05-17 (+20d) | 2012-05-10 → 2012-05-30 (+20d) |  |  |  |  |  |
| 72 | Transfers | 2012-05-11 → 2012-05-31 (+20d) | 2012-05-24 → 2012-06-13 (+20d) |  |  |  |  |  |
| 73 | Early Returns | 2012-04-27 → 2012-05-17 (+20d) | 2012-05-10 → 2012-05-30 (+20d) |  |  |  |  |  |
| 74 | Wait List | 2012-05-11 → 2012-05-31 (+20d) | 2012-05-24 → 2012-06-13 (+20d) |  |  |  |  |  |
| 75 | As-Is Process Maps completed | 2012-05-24 → 2012-06-13 (+20d) | 2012-05-24 → 2012-06-13 (+20d) |  |  |  |  |  |
| 76 | **Data Catagories that are tracked between systems** | 2012-05-25 → 2012-06-14 (+20d) | 2012-06-21 → 2012-07-11 (+20d) |  |  |  |  |  |
| 77 | Housing | 2012-05-25 → 2012-06-14 (+20d) | 2012-06-21 → 2012-07-11 (+20d) |  |  |  |  |  |
| 78 | Biographical | 2012-05-25 → 2012-06-14 (+20d) | 2012-06-21 → 2012-07-11 (+20d) |  |  |  |  |  |
| 79 | Preferences | 2012-05-25 → 2012-06-14 (+20d) | 2012-06-21 → 2012-07-11 (+20d) |  |  |  |  |  |
| 80 | Dual Entry areas / Pain Points | 2012-05-25 → 2012-06-14 (+20d) | 2012-06-21 → 2012-07-11 (+20d) |  |  |  |  |  |
| 81 | Project Wiki | 2012-05-25 → 2012-06-14 (+20d) | 2012-06-21 → 2012-07-11 (+20d) |  |  |  |  |  |
| 82 | Review with Project Team, Stakeholders | 2012-06-22 → 2012-07-12 (+20d) | 2012-06-28 → 2012-07-18 (+20d) |  |  |  |  |  |
| 83 | Discovery Phase Completed | 2012-06-28 → 2012-07-18 (+20d) | 2012-06-28 → 2012-07-18 (+20d) |  |  |  |  |  |
| 84 | Define Phase | 2012-06-29 → 2012-07-19 (+20d) | 2012-09-06 → 2012-09-26 (+20d) |  |  |  |  |  |
| 85 | Design Phase | 2012-09-07 → 2012-09-27 (+20d) | 2012-11-15 → 2012-12-05 (+20d) |  |  |  |  |  |

## Version 7 (saved 2012-04-05)

Last finish 2012-12-05 → 2012-11-20 (-15d).

Added:

| ID | Task | Duration | Start | Finish | Predecessors | Constraint | Resources |
| --- | --- | --- | --- | --- | --- | --- | --- |
| 67 | **As-Is Business Process Descriptions** | 20d | 2012-04-09 | 2012-05-04 |  |  |  |
| 68 | Undergraduate Process | 15d | 2012-04-09 | 2012-04-27 |  | finish no earlier than 2012-04-27 | Ross [40%] |
| 69 | Graduate Process | 15d | 2012-04-09 | 2012-04-27 |  | finish no earlier than 2012-04-27 | Janet [40%] |
| 70 | Present Draft Versions to Project Sponsor | 1d | 2012-04-30 | 2012-04-30 | 68, 69 |  | Ross [40%]; Janet [40%] |
| 71 | Updated completed versions after feedback from Project Sponsors | 5d | 2012-04-30 | 2012-05-04 | 68, 69 | start no earlier than 2012-04-30 | Ross [40%]; Janet [40%] |
| 72 | As-Is Busines Process Documentation completed | 0d | 2012-05-04 | 2012-05-04 | 71 |  |  |
| 78 | High Level Picture | 20d | 2012-05-31 A | 2012-06-27 |  |  | Ross [40%] |
| 79 | Details - with Feeds, Interfaces, | 20d | 2012-05-31 | 2012-06-27 |  |  | Ross [40%] |

Removed: 71 Vacancy; 72 Transfers; 73 Early Returns; 74 Wait List; 76 Data Catagories that are tracked between systems; 77 Housing; 78 Biographical; 79 Preferences; 80 Dual Entry areas / Pain Points; 81 Project Wiki

Changed:

| ID | Task | Start | Finish | Duration | Complete | Total float | Predecessors | Other |
| --- | --- | --- | --- | --- | --- | --- | --- | --- |
| 1 | **Housing Replacement Analysis Project** |  | 2012-12-05 → 2012-11-20 (-15d) | 280d → 269d | 31% → 37% |  |  |  |
| 3 | **Discovery Phase (as-is)** |  | 2012-07-18 → 2012-07-03 (-15d) | 176d → 165d | 40% → 49% | 0d → 100d |  |  |
| 16 | **Discovery Meetings** |  |  |  | 70% → 71% | 0d → 129d |  |  |
| 66 | **Discovery Phase Documentation** | 2012-05-03 → 2012-04-09 A (-24d) | 2012-07-11 → 2012-06-27 (-14d) | 50d → 58d | 0% → 9% | 0d → 104d | 16FS-15d → none |  |
| 73 | **As-Is Process Maps (Visual Micrografx Process Maps)** | 2012-05-03 → 2012-05-01 (-2d) | 2012-06-13 → 2012-05-30 (-14d) | 30d → 22d |  | 0d → 5.5d | none → 70 | was named As-Is Process Maps |
| 74 | Graduate Students | 2012-05-03 → 2012-05-01 (-2d) | 2012-05-16 → 2012-05-28 (+12d) | 10d → 20d |  | 0d → 4d |  |  |
| 75 | Undergraduate Students | 2012-05-03 → 2012-05-01 (-2d) | 2012-05-16 → 2012-05-28 (+12d) | 10d → 20d |  | 0d → 2d |  |  |
| 76 | As-Is Process Maps completed | 2012-06-13 → 2012-05-30 (-14d) | 2012-06-13 → 2012-05-30 (-14d) |  |  | 0d → 2d | 74, 75, Vacancy, Transfers, Early Returns, Wait List → 74, 75FS+2d |  |
| 77 | **System Diagram (IS&T)** | 2011-12-15 A → 2012-05-31 A (+168d) | 2012-02-03 → 2012-06-27 (+145d) | 7d → 20d | 50% → 28% | 77d → 0d | none → 73 |  |
| 80 | Review with Project Team, Stakeholders | 2012-07-12 → 2012-06-28 (-14d) | 2012-07-18 → 2012-07-03 (-15d) | 5d → 4d |  |  | 66 → 77 |  |
| 81 | Discovery Phase Completed | 2012-07-18 → 2012-07-03 (-15d) | 2012-07-18 → 2012-07-03 (-15d) |  |  |  |  |  |
| 82 | Define Phase | 2012-07-19 → 2012-07-04 (-15d) | 2012-09-26 → 2012-09-11 (-15d) |  |  |  |  |  |
| 83 | Design Phase | 2012-09-27 → 2012-09-12 (-15d) | 2012-12-05 → 2012-11-20 (-15d) |  |  |  |  |  |

## Version 8 (saved 2012-04-13)

Last finish 2012-11-20 → 2012-11-30 (+10d).

Added:

| ID | Task | Duration | Start | Finish | Predecessors | Constraint | Resources |
| --- | --- | --- | --- | --- | --- | --- | --- |
| 76 | Present Draft Versions to Project Sponsor | 1d | 2012-05-29 | 2012-05-29 |  | start no earlier than 2012-05-29 | Janet [40%]; Ross [40%] |
| 77 | Updated completed versions after feedback from Project Sponsors | 5d | 2012-05-29 | 2012-06-04 |  | start no earlier than 2012-05-29 | Janet [40%]; Ross [40%] |
| 82 | Present Draft Versions to Project Sponsor | 1d | 2012-07-03 | 2012-07-03 | 81 |  |  |
| 83 | Updated completed versions after feedback from Project Sponsors | 5d | 2012-07-04 | 2012-07-10 | 82 |  |  |
| 84 | As-Is System Diagram completed | 0d | 2012-07-10 | 2012-07-10 | 83 |  |  |

Changed:

| ID | Task | Start | Finish | Duration | Complete | Total float | Predecessors | Other |
| --- | --- | --- | --- | --- | --- | --- | --- | --- |
| 1 | **Housing Replacement Analysis Project** |  | 2012-11-20 → 2012-11-30 (+10d) | 269d → 277d | 37% → 36% |  |  |  |
| 3 | **Discovery Phase (as-is)** |  | 2012-07-03 → 2012-07-13 (+10d) | 165d → 173d | 49% → 48% |  |  |  |
| 17 | **Housing / Lottery** |  | 2012-04-09 → 2012-04-24 (+15d) | 77d → 88d |  | 161d → 158d |  |  |
| 22 | Graduate Students | 2012-04-09 → 2012-04-24 (+15d) | 2012-04-09 → 2012-04-24 (+15d) |  |  | 161d → 158d |  | constraint start no earlier than 2012-04-09 → start no earlier than 2012-04-24 |
| 23 | Summer Students | 2012-04-09 → 2012-04-24 (+15d) | 2012-04-09 → 2012-04-24 (+15d) |  |  | 161d → 158d |  | constraint start no earlier than 2012-04-09 → start no earlier than 2012-04-24 |
| 24 | Post-Doctoral / Faculty | 2012-04-09 → 2012-04-24 (+15d) | 2012-04-09 → 2012-04-24 (+15d) |  |  | 161d → 158d |  | constraint start no earlier than 2012-04-09 → start no earlier than 2012-04-24 |
| 25 | Young Students (Legal Minors) | 2012-04-09 → 2012-04-24 (+15d) | 2012-04-09 → 2012-04-24 (+15d) |  |  | 161d → 158d |  | constraint start no earlier than 2012-04-09 → start no earlier than 2012-04-24 |
| 26 | Outside, Non Affiliated Groups | 2012-04-09 → 2012-04-24 (+15d) | 2012-04-09 → 2012-04-24 (+15d) |  |  | 161d → 158d |  | constraint start no earlier than 2012-04-09 → start no earlier than 2012-04-24 |
| 27 | MIT - Affiliated Groups | 2012-04-09 → 2012-04-24 (+15d) | 2012-04-09 → 2012-04-24 (+15d) |  |  | 161d → 158d |  | constraint start no earlier than 2012-04-09 → start no earlier than 2012-04-24 |
| 28 | Visitors | 2012-04-09 → 2012-04-24 (+15d) | 2012-04-09 → 2012-04-24 (+15d) |  |  | 161d → 158d |  | constraint start no earlier than 2012-04-09 → start no earlier than 2012-04-24 |
| 66 | **Discovery Phase Documentation** |  | 2012-06-27 → 2012-07-10 (+13d) | 58d → 67d |  | 104d → 103d |  |  |
| 68 | Undergraduate Process - Internal review |  |  |  |  | 2d → 11.93d |  | was named Undergraduate Process |
| 69 | Graduate Process - Internal review |  |  |  |  | 2d → 11.93d |  | was named Graduate Process |
| 73 | **As-Is Process Maps (Visual Micrografx Process Maps)** | 2012-05-01 → 2012-05-02 (+1d) | 2012-05-30 → 2012-06-04 (+5d) | 22d → 24d |  | 5.5d → 3.93d |  |  |
| 74 | Graduate Students - Internal review | 2012-05-01 → 2012-05-02 (+1d) | 2012-05-28 → 2012-05-24 (-4d) | 20d → 17d |  | 4d → 10.93d |  | was named Graduate Students; constraint start no earlier than 2012-02-17 → finish no earlier than 2012-05-24 |
| 75 | Undergraduate Students | 2012-05-01 → 2012-05-02 (+1d) | 2012-05-28 → 2012-05-24 (-4d) | 20d → 17d |  | 2d → 10.93d |  | constraint start no earlier than 2012-02-17 → finish no earlier than 2012-05-24 |
| 78 | As-Is Process Maps completed | 2012-05-30 → 2012-06-04 (+5d) | 2012-05-30 → 2012-06-04 (+5d) |  |  | 2d → 3.93d | 74, 75FS+2d → 77 |  |
| 79 | **System Diagram (IS&T)** |  | 2012-06-27 → 2012-07-10 (+13d) | 20d → 29d | 28% → 24% |  |  |  |
| 81 | Details - with Feeds, Interfaces, | 2012-05-31 → 2012-06-05 (+5d) | 2012-06-27 → 2012-07-02 (+5d) |  |  |  |  |  |
| 85 | Review with Project Team, Stakeholders | 2012-06-28 → 2012-07-11 (+13d) | 2012-07-03 → 2012-07-13 (+10d) | 4d → 3d |  |  |  |  |
| 86 | Discovery Phase Completed | 2012-07-03 → 2012-07-13 (+10d) | 2012-07-03 → 2012-07-13 (+10d) |  |  |  |  |  |
| 87 | Define Phase | 2012-07-04 → 2012-07-16 (+12d) | 2012-09-11 → 2012-09-21 (+10d) |  |  |  |  |  |
| 88 | Design Phase | 2012-09-12 → 2012-09-24 (+12d) | 2012-11-20 → 2012-11-30 (+10d) |  |  |  |  |  |

## Version 9 (saved 2012-04-26)

Last finish stays 2012-11-30. Complete tasks 33 → 38.

Changed:

| ID | Task | Start | Finish | Duration | Complete | Total float | Other |
| --- | --- | --- | --- | --- | --- | --- | --- |
| 1 | **Housing Replacement Analysis Project** |  |  |  | 36% → 37% |  |  |
| 3 | **Discovery Phase (as-is)** |  |  |  | 48% → 50% |  |  |
| 16 | **Discovery Meetings** |  |  |  | 71% → 74% |  |  |
| 17 | **Housing / Lottery** |  | 2012-04-24 → 2012-05-02 (+8d) | 88d → 94d |  | 158d → 152d |  |
| 22 | Graduate Students | 2012-04-24 → 2012-05-02 (+8d) | 2012-04-24 → 2012-05-02 (+8d) |  |  | 158d → 152d | constraint start no earlier than 2012-04-24 → start no earlier than 2012-05-02 |
| 23 | Summer Students | 2012-04-24 → 2012-05-02 (+8d) | 2012-04-24 → 2012-05-02 (+8d) |  |  | 158d → 152d | constraint start no earlier than 2012-04-24 → start no earlier than 2012-05-02 |
| 24 | Post-Doctoral / Faculty | 2012-04-24 → 2012-05-02 (+8d) | 2012-04-24 → 2012-05-02 (+8d) |  |  | 158d → 152d | constraint start no earlier than 2012-04-24 → start no earlier than 2012-05-02 |
| 25 | Young Students (Legal Minors) | 2012-04-24 → 2012-05-02 (+8d) | 2012-04-24 → 2012-05-02 (+8d) |  |  | 158d → 152d | constraint start no earlier than 2012-04-24 → start no earlier than 2012-05-02 |
| 26 | Outside, Non Affiliated Groups | 2012-04-24 → 2012-05-02 (+8d) | 2012-04-24 → 2012-05-02 (+8d) |  |  | 158d → 152d | constraint start no earlier than 2012-04-24 → start no earlier than 2012-05-02 |
| 27 | MIT - Affiliated Groups | 2012-04-24 → 2012-05-02 (+8d) | 2012-04-24 → 2012-05-02 (+8d) |  |  | 158d → 152d | constraint start no earlier than 2012-04-24 → start no earlier than 2012-05-02 |
| 28 | Visitors | 2012-04-24 → 2012-05-02 (+8d) | 2012-04-24 → 2012-05-02 (+8d) |  |  | 158d → 152d | constraint start no earlier than 2012-04-24 → start no earlier than 2012-05-02 |
| 55 | Housing Stakeholders - Campus Dining | 2012-04-04 A | 2012-04-04 A |  | 0% → 100% | 172d → none |  |
| 56 | Housing Stakeholders - Tech Cash | 2012-04-04 A | 2012-04-04 A |  | 0% → 100% | 172d → none | resources none → Janet [40%] |
| 57 | UG House Managers | 2012-04-12 A | 2012-04-12 A |  | 0% → 100% | 166d → none | resources Janet [40%] → Ross [40%] |
| 58 | GRAD House Managers | 2012-04-17 A | 2012-04-17 A |  | 0% → 100% | 163d → none | resources none → Janet [40%] |
| 59 | Housing Stakeholders - Card Office / SEMO II | 2012-04-23 A | 2012-04-23 A |  | 0% → 100% | 159d → none |  |
| 60 | FSILG | 2012-04-18 → 2012-05-15 (+27d) | 2012-04-18 → 2012-05-15 (+27d) |  |  | 162d → 143d | constraint start no earlier than 2012-04-18 → start no earlier than 2012-05-15 |

## Version 10 (saved 2012-05-01)

Last finish 2012-11-30 → 2012-12-14 (+14d). Complete tasks 38 → 39.

Changed:

| ID | Task | Start | Finish | Duration | Complete | Total float | Predecessors | Other |
| --- | --- | --- | --- | --- | --- | --- | --- | --- |
| 1 | **Housing Replacement Analysis Project** |  | 2012-11-30 → 2012-12-14 (+14d) | 277d → 287d | 37% → 42% |  |  |  |
| 3 | **Discovery Phase (as-is)** |  | 2012-07-13 → 2012-07-27 (+14d) | 173d → 183d | 50% → 55% |  |  |  |
| 16 | **Discovery Meetings** |  |  |  | 74% → 75% | 137d → 147d |  |  |
| 17 | **Housing / Lottery** |  |  |  | 17% → 25% | 152d → 162d |  |  |
| 19 | Upperclassman | 2012-04-09 A | 2012-04-09 A |  | 0% → 100% | 169d → none |  |  |
| 20 | FSILG | 2012-04-09 → 2012-05-02 (+23d) | 2012-04-09 → 2012-05-02 (+23d) |  |  | 169d → 162d |  | constraint start no earlier than 2012-04-09 → start no earlier than 2012-05-02 |
| 21 | Off Campus Students | 2012-04-09 → 2012-05-02 (+23d) | 2012-04-09 → 2012-05-02 (+23d) |  |  | 169d → 162d |  | constraint start no earlier than 2012-04-09 → start no earlier than 2012-05-02 |
| 66 | **Discovery Phase Documentation** |  | 2012-07-10 → 2012-07-24 (+14d) | 67d → 77d | 9% → 22% |  |  |  |
| 67 | **As-Is Business Process Descriptions** | 2012-04-09 A | 2012-05-04 → 2012-05-11 (+7d) | 20d → 25d | 0% → 42% | 11.93d → 155d |  |  |
| 68 | Undergraduate Process - Internal review | 2012-04-09 A |  |  | 0% → 50% | 11.93d → 18d |  |  |
| 69 | Graduate Process - Internal review | 2012-04-09 A |  |  | 0% → 50% | 11.93d → 18d |  |  |
| 70 | Present Draft Versions to Project Sponsor | 2012-04-30 → 2012-05-04 (+4d) | 2012-04-30 → 2012-05-04 (+4d) |  |  | 2d → 14d |  | constraint none → start no earlier than 2012-05-04 |
| 71 | Updated completed versions after feedback from Project Sponsors | 2012-04-30 → 2012-05-07 (+7d) | 2012-05-04 → 2012-05-11 (+7d) |  |  | 150d → 155d | 68, 69 → 70, 68, 69 |  |
| 72 | As-Is Busines Process Documentation completed | 2012-05-04 → 2012-05-11 (+7d) | 2012-05-04 → 2012-05-11 (+7d) |  |  | 40d → 155d |  |  |
| 73 | **As-Is Process Maps (Visual Micrografx Process Maps)** | 2012-05-02 → 2012-05-07 (+5d) | 2012-06-04 → 2012-06-18 (+14d) | 24d → 31d |  | 3.93d → 0d |  |  |
| 74 | Graduate Students - Internal review | 2012-05-02 → 2012-05-07 (+5d) | 2012-05-24 → 2012-05-29 (+5d) |  |  | 10.93d → 14d |  |  |
| 75 | Undergraduate Students | 2012-05-02 → 2012-05-07 (+5d) | 2012-05-24 → 2012-05-29 (+5d) |  |  | 10.93d → 14d |  |  |
| 76 | Present Draft Versions to Project Sponsor | 2012-05-29 → 2012-06-11 (+13d) | 2012-05-29 → 2012-06-11 (+13d) |  |  | 7.93d → 0d |  | constraint start no earlier than 2012-05-29 → start no earlier than 2012-06-11 |
| 77 | Updated completed versions after feedback from Project Sponsors | 2012-05-29 → 2012-06-12 (+14d) | 2012-06-04 → 2012-06-18 (+14d) |  |  | 3.93d → 0d | none → 76 |  |
| 78 | As-Is Process Maps completed | 2012-06-04 → 2012-06-18 (+14d) | 2012-06-04 → 2012-06-18 (+14d) |  |  | 3.93d → 0d |  |  |
| 79 | **System Diagram (IS&T)** |  | 2012-07-10 → 2012-07-24 (+14d) | 29d → 39d | 24% → 26% |  |  |  |
| 80 | High Level Picture |  | 2012-06-27 → 2012-07-02 (+5d) |  | 55% → 50% | 9d → 16d |  |  |
| 81 | Details - with Feeds, Interfaces, | 2012-06-05 → 2012-06-19 A (+14d) | 2012-07-02 → 2012-07-16 (+14d) |  | 0% → 10% |  |  |  |
| 82 | Present Draft Versions to Project Sponsor | 2012-07-03 → 2012-07-17 (+14d) | 2012-07-03 → 2012-07-17 (+14d) |  |  |  |  |  |
| 83 | Updated completed versions after feedback from Project Sponsors | 2012-07-04 → 2012-07-18 (+14d) | 2012-07-10 → 2012-07-24 (+14d) |  |  |  |  |  |
| 84 | As-Is System Diagram completed | 2012-07-10 → 2012-07-24 (+14d) | 2012-07-10 → 2012-07-24 (+14d) |  |  |  |  |  |
| 85 | Review with Project Team, Stakeholders | 2012-07-11 → 2012-07-25 (+14d) | 2012-07-13 → 2012-07-27 (+14d) |  |  |  |  |  |
| 86 | Discovery Phase Completed | 2012-07-13 → 2012-07-27 (+14d) | 2012-07-13 → 2012-07-27 (+14d) |  |  |  |  |  |
| 87 | Define Phase | 2012-07-16 → 2012-07-30 (+14d) | 2012-09-21 → 2012-10-05 (+14d) |  |  |  |  |  |
| 88 | Design Phase | 2012-09-24 → 2012-10-08 (+14d) | 2012-11-30 → 2012-12-14 (+14d) |  |  |  |  |  |

## Version 11 (saved 2012-05-08)

Last finish 2012-12-14 → 2012-10-26 (-49d). Complete tasks 39 → 43.

Added:

| ID | Task | Duration | Start | Finish | Predecessors | Constraint | Resources |
| --- | --- | --- | --- | --- | --- | --- | --- |
| 56 | **Undergraduate Process** | 24d | 2012-04-09 A | 2012-05-11 |  |  |  |
| 59 | Obtain approval from Project Sponsors | 0d | 2012-05-11 | 2012-05-11 | 58 | start no earlier than 2012-05-11 |  |
| 60 | **Graduate Process** | 27d | 2012-04-09 A | 2012-05-16 |  |  | Janet [40%] |
| 62 | Present Graduate Draft Version to Project Sponsor | 1d | 2012-05-09 | 2012-05-09 | 61 | start no earlier than 2012-05-09 | Janet [40%] |
| 80 | **Identify stakeholder needs** | 20d | 2012-07-02 | 2012-07-27 |  |  |  |
| 81 | Housing Central Office | 20d | 2012-07-02 | 2012-07-27 |  |  | Ross [40%]; Janet [40%] |
| 82 | Housing Managers | 20d | 2012-07-02 | 2012-07-27 |  |  | Ross [40%]; Janet [40%] |
| 83 | Housing Lottery | 20d | 2012-07-02 | 2012-07-27 |  |  | Ross [40%]; Janet [40%] |
| 84 | Housing Filemaker datbases | 20d | 2012-07-02 | 2012-07-27 |  |  | Ross [40%]; Janet [40%] |
| 85 | Undergraduate Housing | 20d | 2012-07-02 | 2012-07-27 |  |  | Ross [40%]; Janet [40%] |
| 86 | Graduate Housing | 20d | 2012-07-02 | 2012-07-27 |  |  | Ross [40%]; Janet [40%] |
| 87 | SFS | 20d | 2012-07-02 | 2012-07-27 |  |  | Ross [40%]; Janet [40%] |
| 88 | HFS | 20d | 2012-07-02 | 2012-07-27 |  |  | Ross [40%]; Janet [40%] |
| 89 | SEMO / Card Access | 20d | 2012-07-02 | 2012-07-27 |  |  | Ross [40%]; Janet [40%] |
| 90 | Campus Dining / Tech Cash | 20d | 2012-07-02 | 2012-07-27 |  |  | Ross [40%]; Janet [40%] |
| 91 | Deans on Call | 20d | 2012-07-02 | 2012-07-27 |  |  | Ross [40%]; Janet [40%] |
| 93 | **Review CBORD capabilities** | 15d | 2012-07-30 | 2012-08-17 | 80 |  | Ross [40%]; Janet [40%] |
| 94 | Review as-is of CBORD Odyssey today | 5d | 2012-07-30 | 2012-08-03 |  |  | Ross [40%]; Janet [40%] |
| 95 | Review where it can replace manual processes | 5d | 2012-08-06 | 2012-08-10 | 94 |  | Ross [40%]; Janet [40%] |
| 96 | Review as-is integration points | 5d | 2012-08-13 | 2012-08-17 | 95 |  | Ross [40%]; Janet [40%] |
| 97 | Training, Site-visit | 5d | 2012-07-30 | 2012-08-03 |  |  | Ross [40%]; Janet [40%] |
| 98 | **Out of Stakeholder Needs, Identify functional Specifications** | 12d | 2012-08-20 | 2012-09-04 | 93 |  | Ross [40%]; Janet [40%] |
| 99 | Housing Central Office | 12d | 2012-08-20 | 2012-09-04 |  |  | Ross [40%]; Janet [40%] |
| 100 | Housing Managers | 12d | 2012-08-20 | 2012-09-04 |  |  | Ross [40%]; Janet [40%] |
| 101 | Housing Lottery | 12d | 2012-08-20 | 2012-09-04 |  |  | Ross [40%]; Janet [40%] |
| 102 | Housing Filemaker datbases | 12d | 2012-08-20 | 2012-09-04 |  |  | Ross [40%]; Janet [40%] |
| 103 | Undergraduate Housing | 12d | 2012-08-20 | 2012-09-04 |  |  | Ross [40%]; Janet [40%] |
| 104 | Graduate Housing | 12d | 2012-08-20 | 2012-09-04 |  |  | Ross [40%]; Janet [40%] |
| 105 | SFS | 12d | 2012-08-20 | 2012-09-04 |  |  | Ross [40%]; Janet [40%] |
| 106 | HFS | 12d | 2012-08-20 | 2012-09-04 |  |  | Ross [40%]; Janet [40%] |
| 107 | SEMO / Card Access | 12d | 2012-08-20 | 2012-09-04 |  |  | Ross [40%]; Janet [40%] |
| 108 | Campus Dining / Tech Cash | 12d | 2012-08-20 | 2012-09-04 |  |  | Ross [40%]; Janet [40%] |
| 109 | Deans on Call | 12d | 2012-08-20 | 2012-09-04 |  |  | Ross [40%]; Janet [40%] |
| 110 | FSILG | 12d | 2012-08-20 | 2012-09-04 |  |  | Ross [40%]; Janet [40%] |
| 111 | Build wireframes | 5d | 2012-09-05 | 2012-09-11 | 98 |  | Ross [40%]; Janet [40%] |
| 112 | Create Functional Specifications | 5d | 2012-09-12 | 2012-09-18 | 111 |  | Ross; Janet [40%] |
| 113 | Review functionality with all stakeholders | 5d | 2012-09-19 | 2012-09-25 | 112 |  | Ross; Janet [40%] |
| 114 | Obtain approval from all stakeholders | 1d | 2012-09-26 | 2012-09-26 | 113 |  | Ross; Janet [40%] |

Removed: 21 Off Campus Students; 23 Summer Students; 24 Post-Doctoral / Faculty; 25 Young Students (Legal Minors); 26 Outside, Non Affiliated Groups; 27 MIT - Affiliated Groups; 28 Visitors; 62 CBORD; 63 Digital Building / Room Setup & Maintenance; 64 Room Rate Code Setup & Maintenance; 65 Current Security, Roles & Authorization, and structures for housing applications

Changed:

| ID | Task | Start | Finish | Duration | Complete | Total float | Predecessors | Other |
| --- | --- | --- | --- | --- | --- | --- | --- | --- |
| 1 | **Housing Replacement Analysis Project** |  | 2012-12-14 → 2012-10-26 (-49d) | 287d → 252d | 42% → 27% |  |  |  |
| 3 | **Discovery Phase (as-is)** |  |  |  | 55% → 73% | 100d → 65d |  |  |
| 16 | **Discovery Meetings** |  | 2012-05-23 → 2012-05-15 (-8d) | 109d → 103d | 75% → 98% | 147d → 94d |  |  |
| 17 | **Housing / Lottery** |  | 2012-05-02 A |  | 25% → 100% | 162d → none |  |  |
| 20 | Graduate Students | 2012-05-02 A | 2012-05-02 A |  | 0% → 100% | 162d → none |  | resources Ross → Janet [40%] |
| 54 | **Discovery Phase Documentation** |  |  |  | 22% → 44% | 103d → 68d |  |  |
| 55 | **As-Is Business Process Descriptions** |  | 2012-05-11 → 2012-05-16 (+5d) | 25d → 27d | 42% → 97% | 155d → 118d |  |  |
| 57 | Undergraduate Process - Internal review |  | 2012-04-27 A |  | 50% → 100% | 18d → none |  |  |
| 58 | Present Undergraduate Draft Version to Project Sponsor | 2012-05-04 A | 2012-05-04 A |  | 0% → 100% | 14d → none | 57, 61 → 57, 60 | was named Present Draft Versions to Project Sponsor; constraint start no earlier than 2012-05-04 → finish no earlier than 2012-05-04; resources Ross [40%]; Janet [40%] → Ross [20%] |
| 61 | Graduate Process - Internal review |  | 2012-04-27 A |  | 50% → 100% | 18d → none |  | constraint finish no earlier than 2012-04-27 → start no earlier than 2012-04-09 |
| 63 | Obtain approval from Project Sponsors | 2012-05-07 → 2012-05-16 (+9d) | 2012-05-11 → 2012-05-16 (+5d) | 5d → 0d |  | 155d → 118d | 58, 57, 61 → 62 | was named Updated completed versions after feedback from Project Sponsors; constraint start no earlier than 2012-04-30 → start no earlier than 2012-05-16; resources Ross [40%]; Janet [40%] → Janet [40%] |
| 64 | As-Is Busines Process Documentation completed | 2012-05-11 → 2012-05-09 (-2d) | 2012-05-11 → 2012-05-09 (-2d) |  |  | 155d → 122d | 63 → 62, 58 | resources none → Ross [40%]; Janet [40%] |
| 65 | **As-Is Process Maps (Visual Micrografx Process Maps)** | 2012-05-07 A |  |  | 0% → 17% |  |  |  |
| 66 | Graduate Students - Internal review | 2012-05-07 A |  |  | 0% → 20% |  |  |  |
| 67 | Undergraduate Students | 2012-05-07 A |  |  | 0% → 20% |  |  |  |
| 71 | **System Diagram (IS&T)** |  |  |  | 26% → 30% |  |  |  |
| 73 | Details - with Feeds, Interfaces, |  |  |  | 10% → 20% |  |  |  |
| 79 | **Define Phase** | 2012-07-30 → 2012-07-02 (-28d) | 2012-10-05 → 2012-09-26 (-9d) | 50d → 63d |  |  | 78 → 78FS-20d |  |
| 92 | FSILG | 2012-05-02 → 2012-07-02 (+61d) | 2012-05-02 → 2012-07-27 (+86d) | 1d → 20d |  | 162d → 0d |  | constraint start no earlier than 2012-05-02 → none; resources Ross → Ross [40%]; Janet [40%] |
| 115 | Design Phase | 2012-10-08 → 2012-08-20 (-49d) | 2012-12-14 → 2012-10-26 (-49d) |  |  |  | 79 → 93 |  |

## Version 12 (saved 2012-05-14)

Last finish stays 2012-10-26.

Added:

| ID | Task | Duration | Start | Finish | Predecessors | Constraint |
| --- | --- | --- | --- | --- | --- | --- |
| 59 | Undergraduate Process - Word Document - Internal Review | 1d | 2012-05-17 | 2012-05-17 | 58 | start no earlier than 2012-05-17 |
| 60 | Present Undergarduate Process - Word Document to Project Sponsors | 1d | 2012-05-18 | 2012-05-18 | 59 |  |
| 65 | Graduate Process - Word Document - Internal Review | 1d? | 2012-05-17 | 2012-05-17 |  | start no earlier than 2012-05-17 |
| 66 | Present Graduate Process - Word Document to Project Sponsors | 1d? | 2012-05-21 | 2012-05-21 | 63, 65 | start no earlier than 2012-05-21 |

Changed:

| ID | Task | Start | Finish | Duration | Complete | Total float | Predecessors | Other |
| --- | --- | --- | --- | --- | --- | --- | --- | --- |
| 1 | **Housing Replacement Analysis Project** |  |  | 252d → 252d? | 27% → 26% |  |  |  |
| 3 | **Discovery Phase (as-is)** |  |  | 183d → 183d? | 73% → 72% |  |  |  |
| 54 | **Discovery Phase Documentation** |  |  | 77d → 77d? | 44% → 42% |  |  |  |
| 55 | **As-Is Business Process Descriptions** |  | 2012-05-16 → 2012-05-21 (+5d) | 27d → 31d? | 97% → 86% | 118d → 114d |  |  |
| 56 | **Undergraduate Process** |  | 2012-05-11 → 2012-05-18 (+7d) | 24d → 30d | 99% → 89% | 97d → 115d |  |  |
| 57 | Undergraduate Process - Internal review (Spreadsheet) |  |  |  |  |  |  | was named Undergraduate Process - Internal review |
| 61 | Obtain approval from Project Sponsors | 2012-05-11 → 2012-05-18 (+7d) | 2012-05-11 → 2012-05-18 (+7d) |  |  | 97d → 115d | 58 → 60 |  |
| 62 | **Graduate Process** |  | 2012-05-16 → 2012-05-21 (+5d) | 27d → 31d? | 94% → 83% | 118d → 114d |  |  |
| 64 | Present Graduate Draft Version to Project Sponsor | 2012-05-09 → 2012-05-21 (+12d) | 2012-05-09 → 2012-05-21 (+12d) |  |  | 98d → 114d |  | constraint start no earlier than 2012-05-09 → start no earlier than 2012-05-21 |
| 67 | Obtain approval from Project Sponsors | 2012-05-16 → 2012-05-21 (+5d) | 2012-05-16 → 2012-05-21 (+5d) |  |  | 118d → 114d | 64 → 66 |  |
| 68 | As-Is Busines Process Documentation completed | 2012-05-09 → 2012-05-21 (+12d) | 2012-05-09 → 2012-05-21 (+12d) |  |  | 122d → 114d |  |  |
| 69 | **As-Is Process Maps (Visual Micrografx Process Maps)** |  | 2012-06-18 → 2012-06-15 (-3d) | 31d → 30d |  | 0d → 1d |  |  |
| 71 | Undergraduate Students - Internal Review |  |  |  |  |  |  | was named Undergraduate Students |
| 72 | Present Draft Versions to Project Sponsor | 2012-06-11 → 2012-06-08 (-3d) | 2012-06-11 → 2012-06-08 (-3d) |  |  | 0d → 1d |  | constraint start no earlier than 2012-06-11 → start no earlier than 2012-06-08 |
| 73 | Updated completed versions after feedback from Project Sponsors | 2012-06-12 → 2012-06-11 (-1d) | 2012-06-18 → 2012-06-15 (-3d) |  |  | 0d → 1d |  |  |
| 74 | As-Is Process Maps completed | 2012-06-18 → 2012-06-15 (-3d) | 2012-06-18 → 2012-06-15 (-3d) |  |  | 0d → 1d |  |  |
| 76 | High Level Picture |  | 2012-07-02 → 2012-06-29 (-3d) |  |  | 16d → 17d |  |  |

## Version 13 (saved 2012-05-22)

Last finish stays 2012-10-26. Complete tasks 43 → 44.

Changed:

| ID | Task | Start | Finish | Duration | Complete | Total float | Predecessors | Other |
| --- | --- | --- | --- | --- | --- | --- | --- | --- |
| 3 | **Discovery Phase (as-is)** |  |  |  | 72% → 69% |  |  |  |
| 54 | **Discovery Phase Documentation** |  |  |  | 42% → 38% |  |  |  |
| 55 | **As-Is Business Process Descriptions** |  | 2012-05-21 → 2012-05-25 (+4d) | 31d? → 34d? | 86% → 89% | 114d → 111d |  |  |
| 56 | **Undergraduate Process** |  | 2012-05-18 → 2012-05-25 (+7d) | 30d → 34d |  | 115d → 111d |  |  |
| 59 | Undergraduate Process - Word Document - Internal Review |  |  |  |  |  |  | resources none → Ross [40%] |
| 60 | Present Undergarduate Process - Word Document to Project Sponsors |  |  |  |  |  |  | resources none → Ross [40%] |
| 61 | Obtain approval from Project Sponsors | 2012-05-18 → 2012-05-25 (+7d) | 2012-05-18 → 2012-05-25 (+7d) |  |  | 115d → 111d |  | constraint start no earlier than 2012-05-11 → start no earlier than 2012-05-25; resources none → Jonathan |
| 62 | **Graduate Process** |  | 2012-05-21 → 2012-05-25 (+4d) | 31d? → 34d? | 83% → 89% | 114d → 111d |  |  |
| 64 | Present Graduate Draft Version to Project Sponsor | 2012-05-21 A | 2012-05-21 A |  | 0% → 100% | 114d → none |  |  |
| 65 | Graduate Process - Word Document - Internal Review |  |  |  |  |  |  | resources none → Janet [40%] |
| 66 | Present Graduate Process - Word Document to Project Sponsors |  |  |  |  |  |  | resources none → Janet [40%] |
| 67 | Obtain approval from Project Sponsors | 2012-05-21 → 2012-05-25 (+4d) | 2012-05-21 → 2012-05-25 (+4d) |  |  | 114d → 111d |  | constraint start no earlier than 2012-05-16 → start no earlier than 2012-05-25; resources Janet [40%] → Jonathan |
| 69 | **As-Is Process Maps (Visual Micrografx Process Maps)** |  | 2012-06-15 → 2012-06-22 (+7d) | 30d → 35d | 17% → 12% | 1d → 0d |  |  |
| 70 | Graduate Students - Internal review |  | 2012-05-29 → 2012-06-08 (+10d) | 17d → 25d | 20% → 14% | 14d → 5d |  | constraint finish no earlier than 2012-05-24 → finish no earlier than 2012-06-08 |
| 71 | Undergraduate Students - Internal Review |  | 2012-05-29 → 2012-06-08 (+10d) | 17d → 25d | 20% → 14% | 14d → 5d |  | constraint finish no earlier than 2012-05-24 → finish no earlier than 2012-06-08 |
| 72 | Present Draft Versions to Project Sponsor | 2012-06-08 → 2012-06-15 (+7d) | 2012-06-08 → 2012-06-15 (+7d) |  |  | 1d → 0d |  | constraint start no earlier than 2012-06-08 → start no earlier than 2012-06-15 |
| 73 | Updated completed versions after feedback from Project Sponsors | 2012-06-11 → 2012-06-18 (+7d) | 2012-06-15 → 2012-06-22 (+7d) |  |  | 1d → 0d | 72 → none | constraint start no earlier than 2012-05-29 → finish no earlier than 2012-06-22 |
| 74 | As-Is Process Maps completed Signoff received | 2012-06-15 → 2012-06-22 (+7d) | 2012-06-15 → 2012-06-22 (+7d) |  |  | 1d → 0d |  | was named As-Is Process Maps completed; resources none → Jonathan |
| 76 | High Level Picture |  | 2012-06-29 → 2012-07-06 (+7d) |  |  | 17d → 12d |  |  |

## Version 14 (saved 2012-06-05)

Last finish 2012-10-26 → 2012-11-28 (+33d). Complete tasks 44 → 47.

Changed:

| ID | Task | Start | Finish | Duration | Complete | Total float | Predecessors | Other |
| --- | --- | --- | --- | --- | --- | --- | --- | --- |
| 1 | **Housing Replacement Analysis Project** |  | 2012-10-26 → 2012-11-28 (+33d) | 252d? → 275d? | 26% → 25% |  |  |  |
| 3 | **Discovery Phase (as-is)** |  | 2012-07-27 → 2012-08-01 (+5d) | 183d? → 186d? | 69% → 60% | 65d → 85d |  |  |
| 16 | **Discovery Meetings** |  | 2012-05-15 → 2012-06-14 (+30d) | 103d → 125d | 98% → 99% | 118d → 95d |  |  |
| 52 | Dean On Call | 2012-05-09 → 2012-06-14 (+36d) | 2012-05-09 → 2012-06-14 (+36d) |  |  | 122d → 95d |  | constraint start no earlier than 2012-05-09 → start no earlier than 2012-06-14 |
| 53 | FSILG | 2012-05-15 A | 2012-05-15 A |  | 0% → 100% | 118d → none |  |  |
| 54 | **Discovery Phase Documentation** |  | 2012-07-24 → 2012-07-27 (+3d) | 77d? → 80d? | 38% → 29% | 68d → 88d |  |  |
| 55 | **As-Is Business Process Descriptions** |  | 2012-05-25 → 2012-06-08 (+14d) | 34d? → 45d? | 89% → 59% | 111d → 123d |  |  |
| 56 | **Undergraduate Process** |  | 2012-05-25 → 2012-06-08 (+14d) | 34d → 45d | 89% → 40% | 111d → 123d |  |  |
| 59 | Undergraduate Process - Word Document - Internal Review | 2012-05-17 → 2012-05-07 (-10d) | 2012-05-17 → 2012-06-06 (+20d) | 1d → 23d |  | 115d → 124d |  | constraint start no earlier than 2012-05-17 → finish no earlier than 2012-06-06 |
| 60 | Present Undergarduate Process - Word Document to Project Sponsors | 2012-05-18 → 2012-06-08 (+21d) | 2012-05-18 → 2012-06-08 (+21d) |  |  | 115d → 123d |  | constraint none → start no earlier than 2012-06-08 |
| 61 | Obtain approval from Project Sponsors | 2012-05-25 → 2012-06-08 (+14d) | 2012-05-25 → 2012-06-08 (+14d) |  |  | 111d → 99d |  |  |
| 62 | **Graduate Process** |  | 2012-05-25 → 2012-06-08 (+14d) | 34d? → 44d? | 89% → 99% | 111d → 124d |  |  |
| 65 | Graduate Process - Word Document - Internal Review | 2012-05-17 → 2012-05-21 A (+4d) | 2012-05-17 → 2012-05-21 A (+4d) | 1d? → 1d | 0% → 100% | 115d → none |  | constraint start no earlier than 2012-05-17 → start no earlier than 2012-05-21 |
| 66 | Present Graduate Process - Word Document to Project Sponsors | 2012-05-21 → 2012-05-22 A (+1d) | 2012-05-21 → 2012-05-22 A (+1d) |  | 0% → 100% | 114d → none |  |  |
| 67 | Obtain approval from Project Sponsors | 2012-05-25 → 2012-06-08 (+14d) | 2012-05-25 → 2012-06-08 (+14d) |  |  | 111d → 124d |  | constraint start no earlier than 2012-05-25 → start no earlier than 2012-06-08 |
| 68 | As-Is Busines Process Documentation completed | 2012-05-21 → 2012-06-08 (+18d) | 2012-05-21 → 2012-06-08 (+18d) |  |  | 114d → 100d | 64, 58 → 67 |  |
| 69 | **As-Is Process Maps (Visual Micrografx Process Maps)** |  | 2012-06-22 → 2012-07-03 (+11d) | 35d → 42d | 12% → 8% |  |  |  |
| 70 | Graduate Students - Internal review |  | 2012-06-08 → 2012-06-29 (+21d) | 25d → 40d | 14% → 9% | 5d → 2d |  | constraint finish no earlier than 2012-06-08 → finish no earlier than 2012-06-29 |
| 71 | Undergraduate Students - Internal Review |  | 2012-06-08 → 2012-06-29 (+21d) | 25d → 40d | 14% → 9% | 5d → 2d |  | constraint finish no earlier than 2012-06-08 → finish no earlier than 2012-06-29 |
| 72 | Present Draft Versions to Project Sponsor | 2012-06-15 → 2012-07-03 (+18d) | 2012-06-15 → 2012-07-03 (+18d) |  |  |  |  | constraint start no earlier than 2012-06-15 → start no earlier than 2012-07-03 |
| 73 | Updated completed versions after feedback from Project Sponsors | 2012-06-18 → 2012-07-03 (+15d) | 2012-06-22 → 2012-07-03 (+11d) | 5d → 1d |  |  |  | constraint finish no earlier than 2012-06-22 → finish no earlier than 2012-07-03 |
| 74 | As-Is Process Maps completed Signoff received | 2012-06-22 → 2012-07-03 (+11d) | 2012-06-22 → 2012-07-03 (+11d) |  |  |  |  |  |
| 75 | **System Diagram (IS&T)** |  | 2012-07-24 → 2012-07-27 (+3d) | 39d → 42d | 30% → 26% |  |  |  |
| 76 | High Level Picture |  | 2012-07-06 → 2012-07-17 (+11d) |  |  | 12d → 8d |  |  |
| 77 | Details - with Feeds, Interfaces, | 2012-06-19 A → 2012-07-04 (+15d) | 2012-07-16 → 2012-07-19 (+3d) | 20d → 12d | 20% → 0% |  |  |  |
| 78 | Present Draft Versions to Project Sponsor | 2012-07-17 → 2012-07-20 (+3d) | 2012-07-17 → 2012-07-20 (+3d) |  |  |  |  |  |
| 79 | Updated completed versions after feedback from Project Sponsors | 2012-07-18 → 2012-07-23 (+5d) | 2012-07-24 → 2012-07-27 (+3d) |  |  |  |  |  |
| 80 | As-Is System Diagram completed | 2012-07-24 → 2012-07-27 (+3d) | 2012-07-24 → 2012-07-27 (+3d) |  |  |  |  |  |
| 81 | Review with Project Team, Stakeholders | 2012-07-25 → 2012-07-30 (+5d) | 2012-07-27 → 2012-08-01 (+5d) |  |  |  |  |  |
| 82 | Discovery Phase Completed | 2012-07-27 → 2012-08-01 (+5d) | 2012-07-27 → 2012-08-01 (+5d) |  |  |  |  |  |
| 83 | **Define Phase** | 2012-07-02 → 2012-08-02 (+31d) | 2012-09-26 → 2012-10-29 (+33d) |  |  |  | 82FS-20d → 82 |  |
| 84 | **Identify stakeholder needs** | 2012-07-02 → 2012-08-02 (+31d) | 2012-07-27 → 2012-08-29 (+33d) |  |  |  |  |  |
| 85 | Housing Central Office | 2012-07-02 → 2012-08-02 (+31d) | 2012-07-27 → 2012-08-29 (+33d) |  |  |  |  |  |
| 86 | Housing Managers | 2012-07-02 → 2012-08-02 (+31d) | 2012-07-27 → 2012-08-29 (+33d) |  |  |  |  |  |
| 87 | Housing Lottery | 2012-07-02 → 2012-08-02 (+31d) | 2012-07-27 → 2012-08-29 (+33d) |  |  |  |  |  |
| 88 | Housing Filemaker datbases | 2012-07-02 → 2012-08-02 (+31d) | 2012-07-27 → 2012-08-29 (+33d) |  |  |  |  |  |
| 89 | Undergraduate Housing | 2012-07-02 → 2012-08-02 (+31d) | 2012-07-27 → 2012-08-29 (+33d) |  |  |  |  |  |
| 90 | Graduate Housing | 2012-07-02 → 2012-08-02 (+31d) | 2012-07-27 → 2012-08-29 (+33d) |  |  |  |  |  |
| 91 | SFS | 2012-07-02 → 2012-08-02 (+31d) | 2012-07-27 → 2012-08-29 (+33d) |  |  |  |  |  |
| 92 | HFS | 2012-07-02 → 2012-08-02 (+31d) | 2012-07-27 → 2012-08-29 (+33d) |  |  |  |  |  |
| 93 | SEMO / Card Access | 2012-07-02 → 2012-08-02 (+31d) | 2012-07-27 → 2012-08-29 (+33d) |  |  |  |  |  |
| 94 | Campus Dining / Tech Cash | 2012-07-02 → 2012-08-02 (+31d) | 2012-07-27 → 2012-08-29 (+33d) |  |  |  |  |  |
| 95 | Deans on Call | 2012-07-02 → 2012-08-02 (+31d) | 2012-07-27 → 2012-08-29 (+33d) |  |  |  |  |  |
| 96 | FSILG | 2012-07-02 → 2012-08-02 (+31d) | 2012-07-27 → 2012-08-29 (+33d) |  |  |  |  |  |
| 97 | **Review CBORD capabilities** | 2012-07-30 → 2012-08-30 (+31d) | 2012-08-17 → 2012-09-19 (+33d) |  |  |  |  |  |
| 98 | Review as-is of CBORD Odyssey today | 2012-07-30 → 2012-08-30 (+31d) | 2012-08-03 → 2012-09-05 (+33d) |  |  |  |  |  |
| 99 | Review where it can replace manual processes | 2012-08-06 → 2012-09-06 (+31d) | 2012-08-10 → 2012-09-12 (+33d) |  |  |  |  |  |
| 100 | Review as-is integration points | 2012-08-13 → 2012-09-13 (+31d) | 2012-08-17 → 2012-09-19 (+33d) |  |  |  |  |  |
| 101 | Training, Site-visit | 2012-07-30 → 2012-08-30 (+31d) | 2012-08-03 → 2012-09-05 (+33d) |  |  |  |  |  |
| 102 | **Out of Stakeholder Needs, Identify functional Specifications** | 2012-08-20 → 2012-09-20 (+31d) | 2012-09-04 → 2012-10-05 (+31d) |  |  |  |  |  |
| 103 | Housing Central Office | 2012-08-20 → 2012-09-20 (+31d) | 2012-09-04 → 2012-10-05 (+31d) |  |  |  |  |  |
| 104 | Housing Managers | 2012-08-20 → 2012-09-20 (+31d) | 2012-09-04 → 2012-10-05 (+31d) |  |  |  |  |  |
| 105 | Housing Lottery | 2012-08-20 → 2012-09-20 (+31d) | 2012-09-04 → 2012-10-05 (+31d) |  |  |  |  |  |
| 106 | Housing Filemaker datbases | 2012-08-20 → 2012-09-20 (+31d) | 2012-09-04 → 2012-10-05 (+31d) |  |  |  |  |  |
| 107 | Undergraduate Housing | 2012-08-20 → 2012-09-20 (+31d) | 2012-09-04 → 2012-10-05 (+31d) |  |  |  |  |  |
| 108 | Graduate Housing | 2012-08-20 → 2012-09-20 (+31d) | 2012-09-04 → 2012-10-05 (+31d) |  |  |  |  |  |
| 109 | SFS | 2012-08-20 → 2012-09-20 (+31d) | 2012-09-04 → 2012-10-05 (+31d) |  |  |  |  |  |
| 110 | HFS | 2012-08-20 → 2012-09-20 (+31d) | 2012-09-04 → 2012-10-05 (+31d) |  |  |  |  |  |
| 111 | SEMO / Card Access | 2012-08-20 → 2012-09-20 (+31d) | 2012-09-04 → 2012-10-05 (+31d) |  |  |  |  |  |
| 112 | Campus Dining / Tech Cash | 2012-08-20 → 2012-09-20 (+31d) | 2012-09-04 → 2012-10-05 (+31d) |  |  |  |  |  |
| 113 | Deans on Call | 2012-08-20 → 2012-09-20 (+31d) | 2012-09-04 → 2012-10-05 (+31d) |  |  |  |  |  |
| 114 | FSILG | 2012-08-20 → 2012-09-20 (+31d) | 2012-09-04 → 2012-10-05 (+31d) |  |  |  |  |  |
| 115 | Build wireframes | 2012-09-05 → 2012-10-08 (+33d) | 2012-09-11 → 2012-10-12 (+31d) |  |  |  |  |  |
| 116 | Create Functional Specifications | 2012-09-12 → 2012-10-15 (+33d) | 2012-09-18 → 2012-10-19 (+31d) |  |  |  |  |  |
| 117 | Review functionality with all stakeholders | 2012-09-19 → 2012-10-22 (+33d) | 2012-09-25 → 2012-10-26 (+31d) |  |  |  |  |  |
| 118 | Obtain approval from all stakeholders | 2012-09-26 → 2012-10-29 (+33d) | 2012-09-26 → 2012-10-29 (+33d) |  |  |  |  |  |
| 119 | Design Phase | 2012-08-20 → 2012-09-20 (+31d) | 2012-10-26 → 2012-11-28 (+33d) |  |  |  |  |  |

## Version 15 (saved 2012-06-13)

Last finish stays 2012-11-28. Complete tasks 47 → 48.

Changed:

| ID | Task | Start | Finish | Complete | Total float |
| --- | --- | --- | --- | --- | --- |
| 1 | **Housing Replacement Analysis Project** |  |  | 25% → 28% |  |
| 3 | **Discovery Phase (as-is)** |  |  | 60% → 67% |  |
| 54 | **Discovery Phase Documentation** |  |  | 29% → 41% |  |
| 55 | **As-Is Business Process Descriptions** |  |  | 59% → 98% |  |
| 56 | **Undergraduate Process** |  |  | 40% → 98% |  |
| 59 | Undergraduate Process - Word Document - Internal Review | 2012-05-07 A | 2012-06-06 A | 0% → 100% | 124d → none |

## Version 16 (saved 2012-06-29)

Last finish 2012-11-28 → 2012-12-17 (+19d). Complete tasks 48 → 50.

Changed:

| ID | Task | Start | Finish | Duration | Complete | Total float | Other |
| --- | --- | --- | --- | --- | --- | --- | --- |
| 1 | **Housing Replacement Analysis Project** |  | 2012-11-28 → 2012-12-17 (+19d) | 275d? → 288d? | 28% → 32% |  |  |
| 3 | **Discovery Phase (as-is)** |  | 2012-08-01 → 2012-08-20 (+19d) | 186d? → 199d? | 67% → 78% |  |  |
| 16 | **Discovery Meetings** |  | 2012-06-14 A |  | 99% → 100% | 95d → none |  |
| 52 | Dean On Call | 2012-06-14 A | 2012-06-14 A |  | 0% → 100% | 95d → none | resources none → Ross [40%] |
| 54 | **Discovery Phase Documentation** |  | 2012-07-27 → 2012-08-15 (+19d) | 80d? → 93d? | 41% → 61% |  |  |
| 55 | **As-Is Business Process Descriptions** |  | 2012-06-08 → 2012-06-29 (+21d) | 45d? → 59d? | 98% → 99% | 123d → 122d |  |
| 56 | **Undergraduate Process** |  | 2012-06-08 → 2012-06-29 (+21d) | 45d → 59d | 98% → 99% | 123d → 122d |  |
| 60 | Present Undergarduate Process - Word Document to Project Sponsors | 2012-06-08 → 2012-06-20 A (+12d) | 2012-06-08 → 2012-06-20 A (+12d) |  | 0% → 100% | 123d → none | constraint start no earlier than 2012-06-08 → finish no earlier than 2012-06-20 |
| 61 | Obtain approval from Project Sponsors | 2012-06-08 → 2012-06-29 (+21d) | 2012-06-08 → 2012-06-29 (+21d) |  |  | 99d → 122d | constraint start no earlier than 2012-05-25 → start no earlier than 2012-06-29 |
| 62 | **Graduate Process** |  | 2012-06-08 → 2012-06-29 (+21d) | 44d? → 59d? |  | 100d → 122d |  |
| 67 | Obtain approval from Project Sponsors | 2012-06-08 → 2012-06-29 (+21d) | 2012-06-08 → 2012-06-29 (+21d) |  |  | 124d → 122d | constraint start no earlier than 2012-06-08 → start no earlier than 2012-06-29 |
| 68 | As-Is Busines Process Documentation completed | 2012-06-08 → 2012-06-29 (+21d) | 2012-06-08 → 2012-06-29 (+21d) |  |  | 100d → 122d | constraint none → start no earlier than 2012-06-29 |
| 69 | **As-Is Process Maps (Visual Micrografx Process Maps)** |  | 2012-07-03 → 2012-07-20 (+17d) | 42d → 55d | 8% → 49% |  |  |
| 70 | Graduate Students - Internal review |  |  |  | 9% → 50% | 2d → 15d |  |
| 71 | Undergraduate Students - Internal Review |  |  |  | 9% → 50% | 2d → 5d |  |
| 72 | Present Draft Versions to Project Sponsor | 2012-07-03 → 2012-07-18 (+15d) | 2012-07-03 → 2012-07-18 (+15d) |  |  | 0d → -8d | constraint start no earlier than 2012-07-03 → start no earlier than 2012-07-18 |
| 73 | Updated completed versions after feedback from Project Sponsors | 2012-07-03 → 2012-07-20 (+17d) | 2012-07-03 → 2012-07-20 (+17d) |  |  | 0d → -10d | constraint finish no earlier than 2012-07-03 → start no earlier than 2012-07-20 |
| 74 | As-Is Process Maps completed Signoff received | 2012-07-03 → 2012-07-20 (+17d) | 2012-07-03 → 2012-07-20 (+17d) |  |  | 0d → -10d |  |
| 75 | **System Diagram (IS&T)** |  | 2012-07-27 → 2012-08-15 (+19d) | 42d → 55d |  |  |  |
| 76 | High Level Picture |  | 2012-07-17 → 2012-08-03 (+17d) |  |  |  |  |
| 77 | Details - with Feeds, Interfaces, | 2012-07-04 → 2012-07-23 (+19d) | 2012-07-19 → 2012-08-07 (+19d) |  |  |  |  |
| 78 | Present Draft Versions to Project Sponsor | 2012-07-20 → 2012-08-08 (+19d) | 2012-07-20 → 2012-08-08 (+19d) |  |  |  |  |
| 79 | Updated completed versions after feedback from Project Sponsors | 2012-07-23 → 2012-08-09 (+17d) | 2012-07-27 → 2012-08-15 (+19d) |  |  |  |  |
| 80 | As-Is System Diagram completed | 2012-07-27 → 2012-08-15 (+19d) | 2012-07-27 → 2012-08-15 (+19d) |  |  |  |  |
| 81 | Review with Project Team, Stakeholders | 2012-07-30 → 2012-08-16 (+17d) | 2012-08-01 → 2012-08-20 (+19d) |  |  |  |  |
| 82 | Discovery Phase Completed | 2012-08-01 → 2012-08-20 (+19d) | 2012-08-01 → 2012-08-20 (+19d) |  |  |  |  |
| 83 | **Define Phase** | 2012-08-02 → 2012-08-21 (+19d) | 2012-10-29 → 2012-11-15 (+17d) |  |  |  |  |
| 84 | **Identify stakeholder needs** | 2012-08-02 → 2012-08-21 (+19d) | 2012-08-29 → 2012-09-17 (+19d) |  |  |  |  |
| 85 | Housing Central Office | 2012-08-02 → 2012-08-21 (+19d) | 2012-08-29 → 2012-09-17 (+19d) |  |  |  |  |
| 86 | Housing Managers | 2012-08-02 → 2012-08-21 (+19d) | 2012-08-29 → 2012-09-17 (+19d) |  |  |  |  |
| 87 | Housing Lottery | 2012-08-02 → 2012-08-21 (+19d) | 2012-08-29 → 2012-09-17 (+19d) |  |  |  |  |
| 88 | Housing Filemaker datbases | 2012-08-02 → 2012-08-21 (+19d) | 2012-08-29 → 2012-09-17 (+19d) |  |  |  |  |
| 89 | Undergraduate Housing | 2012-08-02 → 2012-08-21 (+19d) | 2012-08-29 → 2012-09-17 (+19d) |  |  |  |  |
| 90 | Graduate Housing | 2012-08-02 → 2012-08-21 (+19d) | 2012-08-29 → 2012-09-17 (+19d) |  |  |  |  |
| 91 | SFS | 2012-08-02 → 2012-08-21 (+19d) | 2012-08-29 → 2012-09-17 (+19d) |  |  |  |  |
| 92 | HFS | 2012-08-02 → 2012-08-21 (+19d) | 2012-08-29 → 2012-09-17 (+19d) |  |  |  |  |
| 93 | SEMO / Card Access | 2012-08-02 → 2012-08-21 (+19d) | 2012-08-29 → 2012-09-17 (+19d) |  |  |  |  |
| 94 | Campus Dining / Tech Cash | 2012-08-02 → 2012-08-21 (+19d) | 2012-08-29 → 2012-09-17 (+19d) |  |  |  |  |
| 95 | Deans on Call | 2012-08-02 → 2012-08-21 (+19d) | 2012-08-29 → 2012-09-17 (+19d) |  |  |  |  |
| 96 | FSILG | 2012-08-02 → 2012-08-21 (+19d) | 2012-08-29 → 2012-09-17 (+19d) |  |  |  |  |
| 97 | **Review CBORD capabilities** | 2012-08-30 → 2012-09-18 (+19d) | 2012-09-19 → 2012-10-08 (+19d) |  |  |  |  |
| 98 | Review as-is of CBORD Odyssey today | 2012-08-30 → 2012-09-18 (+19d) | 2012-09-05 → 2012-09-24 (+19d) |  |  |  |  |
| 99 | Review where it can replace manual processes | 2012-09-06 → 2012-09-25 (+19d) | 2012-09-12 → 2012-10-01 (+19d) |  |  |  |  |
| 100 | Review as-is integration points | 2012-09-13 → 2012-10-02 (+19d) | 2012-09-19 → 2012-10-08 (+19d) |  |  |  |  |
| 101 | Training, Site-visit | 2012-08-30 → 2012-09-18 (+19d) | 2012-09-05 → 2012-09-24 (+19d) |  |  |  |  |
| 102 | **Out of Stakeholder Needs, Identify functional Specifications** | 2012-09-20 → 2012-10-09 (+19d) | 2012-10-05 → 2012-10-24 (+19d) |  |  |  |  |
| 103 | Housing Central Office | 2012-09-20 → 2012-10-09 (+19d) | 2012-10-05 → 2012-10-24 (+19d) |  |  |  |  |
| 104 | Housing Managers | 2012-09-20 → 2012-10-09 (+19d) | 2012-10-05 → 2012-10-24 (+19d) |  |  |  |  |
| 105 | Housing Lottery | 2012-09-20 → 2012-10-09 (+19d) | 2012-10-05 → 2012-10-24 (+19d) |  |  |  |  |
| 106 | Housing Filemaker datbases | 2012-09-20 → 2012-10-09 (+19d) | 2012-10-05 → 2012-10-24 (+19d) |  |  |  |  |
| 107 | Undergraduate Housing | 2012-09-20 → 2012-10-09 (+19d) | 2012-10-05 → 2012-10-24 (+19d) |  |  |  |  |
| 108 | Graduate Housing | 2012-09-20 → 2012-10-09 (+19d) | 2012-10-05 → 2012-10-24 (+19d) |  |  |  |  |
| 109 | SFS | 2012-09-20 → 2012-10-09 (+19d) | 2012-10-05 → 2012-10-24 (+19d) |  |  |  |  |
| 110 | HFS | 2012-09-20 → 2012-10-09 (+19d) | 2012-10-05 → 2012-10-24 (+19d) |  |  |  |  |
| 111 | SEMO / Card Access | 2012-09-20 → 2012-10-09 (+19d) | 2012-10-05 → 2012-10-24 (+19d) |  |  |  |  |
| 112 | Campus Dining / Tech Cash | 2012-09-20 → 2012-10-09 (+19d) | 2012-10-05 → 2012-10-24 (+19d) |  |  |  |  |
| 113 | Deans on Call | 2012-09-20 → 2012-10-09 (+19d) | 2012-10-05 → 2012-10-24 (+19d) |  |  |  |  |
| 114 | FSILG | 2012-09-20 → 2012-10-09 (+19d) | 2012-10-05 → 2012-10-24 (+19d) |  |  |  |  |
| 115 | Build wireframes | 2012-10-08 → 2012-10-25 (+17d) | 2012-10-12 → 2012-10-31 (+19d) |  |  |  |  |
| 116 | Create Functional Specifications | 2012-10-15 → 2012-11-01 (+17d) | 2012-10-19 → 2012-11-07 (+19d) |  |  |  |  |
| 117 | Review functionality with all stakeholders | 2012-10-22 → 2012-11-08 (+17d) | 2012-10-26 → 2012-11-14 (+19d) |  |  |  |  |
| 118 | Obtain approval from all stakeholders | 2012-10-29 → 2012-11-15 (+17d) | 2012-10-29 → 2012-11-15 (+17d) |  |  |  |  |
| 119 | Design Phase | 2012-09-20 → 2012-10-09 (+19d) | 2012-11-28 → 2012-12-17 (+19d) |  |  |  |  |
